# Intranet InverUnion

Schedule from MS Project, 2004-05-03 to 2005-12-22, status date 2004-04-29.
GSM

## Calendars

- Standard: Mon-Fri 08:00-12:00, 13:00-17:00; Sat-Sun off.

## Resources

| Resource |
| --- |
| Hernán Rosas |
| Olga Lorenzo |
| Jamile Track |
| Giovanni Savoca |
| Simón Cordido |
| Listbeth Rojas |

## Schedule

| ID | WBS | Task | Type | Duration | Start | Finish | Predecessors | Total slack | Free slack | Resources | Work |
| --- | --- | --- | --- | --- | --- | --- | --- | --- | --- | --- | --- |
| 1 | 1 | Arranque de Proyecto |  | 1d | 2004-05-03 | 2004-05-03 |  | 409.5d | 0d | Hernán Rosas; Olga Lorenzo; Jamile Track; Giovanni Savoca | 32h |
| 2 | 2 | **Infraestructura e Instalación N2C** |  | 11d? | 2004-05-04 | 2004-05-18 | 1 | 416.5d |  | Giovanni Savoca | 256h |
| 3 | 2.1 | Comunicación |  | 1d | 2004-05-04 | 2004-05-04 |  | 416.5d | 0d | Giovanni Savoca | 8h |
| 4 | 2.2 | Análisis del Ambiente/Plan de Trabajo |  | 5d | 2004-05-05 | 2004-05-11 | 3 | 416.5d | 0d | Simón Cordido; Giovanni Savoca | 80h |
| 5 | 2.3 | Instalar/Configurar Apache |  | 1d | 2004-05-12 | 2004-05-12 | 4 | 416.5d | 0d | Simón Cordido; Giovanni Savoca | 16h |
| 6 | 2.4 | **Instalar/Configurar MySQL** |  | 2d | 2004-05-13 | 2004-05-14 | 5 | 416.5d | 0d | Simón Cordido; Giovanni Savoca | 32h |
| 7 | 2.4.1 | Ambiente de Producción |  | 1d | 2004-05-13 | 2004-05-13 |  | 416.5d | 0d |  |  |
| 8 | 2.4.2 | Ambiente de Desarrollo y Pruebas |  | 1d | 2004-05-14 | 2004-05-14 | 7 | 416.5d |  |  |  |
| 9 | 2.5 | **Instalar/Configurar Net2Client** |  | 2d | 2004-05-17 | 2004-05-18 | 6 | 416.5d |  | Simón Cordido; Giovanni Savoca | 32h |
| 10 | 2.5.1 | Crear ambiente de Producción |  | 2d | 2004-05-17 | 2004-05-18 |  | 416.5d |  |  |  |
| 11 | 2.5.2 | Crear ambiente de Desarrollo y Pruebas |  | 2d | 2004-05-17 | 2004-05-18 |  | 416.5d |  |  |  |
| 12 | 2.6 | Pruebas |  | 1d? | 2004-05-04 | 2004-05-04 |  | 425.5d | 0d |  |  |
| 13 | 2.7 | Aceptación |  | 1d? | 2004-05-05 | 2004-05-05 | 12 | 425.5d |  |  |  |
| 14 | 3 | **Portal Intranet y Comunicaciones Corporativas** |  | 18d | 2004-05-04 | 2004-05-27 | 1 | 409.5d |  | Olga Lorenzo; Hernán Rosas | 520h |
| 15 | 3.1 | Kick Off |  | 1d | 2004-05-04 | 2004-05-04 |  | 409.5d | 0d | Olga Lorenzo; Jamile Track | 16h |
| 16 | 3.2 | Definir Estructura y Diseño del Portal |  | 1d | 2004-05-05 | 2004-05-05 | 15 | 409.5d | 0d | Olga Lorenzo; Jamile Track | 16h |
| 17 | 3.3 | Adaptación Web in a Box |  | 3d | 2004-05-06 | 2004-05-10 | 16 | 409.5d | 0d | Hernán Rosas | 24h |
| 18 | 3.4 | Contenido del Portal |  | 2d | 2004-05-06 | 2004-05-07 | 16 | 410.5d | 1d | Olga Lorenzo | 16h |
| 19 | 3.5 | Construir el Portal |  | 3d | 2004-05-11 | 2004-05-13 | 17, 18 | 409.5d | 0d | Olga Lorenzo | 24h |
| 20 | 3.6 | **Comunicaciones Corporativas** |  | 7d | 2004-05-14 | 2004-05-24 | 19 | 409.5d |  | Olga Lorenzo | 112h |
| 21 | 3.6.1 | Módulo de Noticias (Aplicación) |  | 5d | 2004-05-14 | 2004-05-20 |  | 409.5d | 0d | Olga Lorenzo | 40h |
| 22 | 3.6.2 | Módulo de Resumen de Prensa |  | 2d | 2004-05-21 | 2004-05-24 | 21 | 409.5d | 0d | Olga Lorenzo | 16h |
| 23 | 3.7 | Pruebas |  | 1d | 2004-05-25 | 2004-05-25 | 22 | 409.5d | 0d | Olga Lorenzo | 8h |
| 24 | 3.8 | Aceptación | milestone | 0d | 2004-05-25 | 2004-05-25 | 23 | 409.5d | 0d | Olga Lorenzo |  |
| 25 | 3.9 | Adiestramiento Comunicaciones Corporativas |  | 2d | 2004-05-26 | 2004-05-27 | 24 | 409.5d |  | Olga Lorenzo | 16h |

Notes:
- 2: Diseñar y configurar los procesos de desarrollo, pruebas y actualización (y roll back) del Sistema. Es ideal mantener el trabajo remoto.
- 3: e-mail para reunión para definir la infraestructura de hardware y software.
- 4: Contingencia, Respaldo y Recuperación. / Espacio en Disco, Red, Sistema Operativo, Apache, MySQL, N2C.
- 15: Definir Roles: Administrador, Dueño del Módulo, Quién puede modificar, a quien adiestramos, fechas previsibles (Plan de Trabajo con Reuniones, Aprobaciones, Adiestramiento). / El tiempo incluye la preparación, el kick off y el resumen y documentación de lo acordado. / Definir el Login al Portal.
- 21: Módulo de Noticias. Es dinámico y se presentan según el usuario. En el directorio tendremos información de a quien le enviaremos. Estructura con los GRUPOS DE DISTRIBUCIÓN.
- 25: Adiestramiento de Web in a Box y la Funcionalidad de los Módulos.

| ID | WBS | Task | Type | Duration | Start | Finish | Predecessors | Total slack | Resources | Work |
| --- | --- | --- | --- | --- | --- | --- | --- | --- | --- | --- |
| 26 | 4 | **Directorio** |  | 14.5d | 2004-05-03 | 2004-05-21 |  | 0d | Jamile Track | 272h |
| 27 | 4.1 | Kick Off |  | 2d | 2004-05-03 | 2004-05-04 |  | 0d | Jamile Track; Olga Lorenzo | 32h |
| 28 | 4.2 | **Trabajadores** |  | 5.5d | 2004-05-05 | 2004-05-12 | 27 | 0d |  | 52h |
| 29 | 4.2.1 | Definir Base de Datos |  | 1d | 2004-05-05 | 2004-05-05 |  | 0d | Jamile Track; Olga Lorenzo | 16h |
| 30 | 4.2.2 | Carga Inicial de lo Existente |  | 0.5d | 2004-05-06 | 2004-05-06 | 29 | 0d | Jamile Track | 4h |
| 31 | 4.2.3 | Manejo de Grupos de Distribución |  | 1d | 2004-05-06 | 2004-05-07 | 30 | 0d | Jamile Track | 8h |
| 32 | 4.2.4 | Reportes, Vistas y Ayuda |  | 2d | 2004-05-07 | 2004-05-11 | 31 | 0d | Jamile Track | 16h |
| 33 | 4.2.5 | Auto-Actualización de la Data (Usuario) |  | 1d | 2004-05-11 | 2004-05-12 | 32 | 0d | Jamile Track | 8h |
| 34 | 4.3 | **Relacionados** |  | 5.5d | 2004-05-12 | 2004-05-19 | 28 | 0d |  | 60h |
| 35 | 4.3.1 | Definir Base de Datos |  | 2d | 2004-05-12 | 2004-05-14 |  | 0d | Jamile Track; Olga Lorenzo | 32h |
| 36 | 4.3.2 | Carga Inicial Parcial (Hoja Excel) |  | 0.5d | 2004-05-14 | 2004-05-14 | 35 | 0d | Jamile Track | 4h |
| 37 | 4.3.3 | Reportes, Vistas y Ayuda |  | 2d | 2004-05-17 | 2004-05-18 | 36 | 0d | Jamile Track | 16h |
| 38 | 4.3.4 | Auto-Actualización de la Data (Usuario) |  | 1d | 2004-05-19 | 2004-05-19 | 37 | 0d | Jamile Track | 8h |
| 39 | 4.4 | Pruebas |  | 1d | 2004-05-20 | 2004-05-20 | 34 | 0d | Jamile Track | 8h |
| 40 | 4.5 | Aceptación | milestone | 0d | 2004-05-20 | 2004-05-20 | 39 | 0d | Jamile Track |  |
| 41 | 4.6 | Adiestramiento T/I |  | 0.5d | 2004-05-21 | 2004-05-21 | 40 | 0d | Jamile Track | 4h |
| 42 | 5 | **Interfaces del Directorio** |  | 20d | 2004-05-21 | 2004-06-18 | 26 | 0d |  | 40h |
| 43 | 5.1 | Identificación de Interfaces |  | 2d | 2004-05-21 | 2004-05-25 |  | 0d | Jamile Track | 16h |
| 44 | 5.2 | Diseño de Interface |  | 3d | 2004-05-25 | 2004-05-28 | 43 | 0d | Jamile Track | 24h |
| 45 | 5.3 | Construcción de las Interfaces |  | 15d | 2004-05-28 | 2004-06-18 | 44 | 0d |  |  |
| 46 | 6 | **Manejo de Solicitudes** |  | 10d | 2004-06-18 | 2004-07-02 | 42 | 0d | Jamile Track; Olga Lorenzo | 320h |
| 47 | 6.1 | Análisis del Proceso de Solicitudes |  | 2d | 2004-06-18 | 2004-06-22 |  | 0d | Jamile Track; Olga Lorenzo | 32h |
| 48 | 6.2 | Diseño del Proceso de Solicitudes |  | 3d | 2004-06-22 | 2004-06-25 | 47 | 0d | Jamile Track; Olga Lorenzo | 48h |
| 49 | 6.3 | Construcción del Proceso de Solicitudes |  | 4d | 2004-06-25 | 2004-07-01 | 48 | 0d | Jamile Track; Olga Lorenzo | 64h |
| 50 | 6.4 | Pruebas Internas |  | 1d | 2004-07-01 | 2004-07-02 | 49 | 0d | Jamile Track; Olga Lorenzo | 16h |

Notes:
- 26: Debe tener interfaz con la Central Telefónica
- 27: Definir Roles: Administrador, Dueño del Módulo, Quién puede modificar, a quien adiestramos, fechas previsibles (Plan de Trabajo con Reuniones, Aprobaciones, Adiestramiento).
- 28: Definir la Estructura, las Empresas, los Organigramas, su Ubicación Geográfica y la Fuente de Datos (donde están los datos), quien actualiza la información (Manual o Automática: desde o hacia que sistemas y con que frecuencia, que programas).
- 29: Incluir en el Diseño para la posibilidad del Programa de Listas de Distribución (Programa para el Proceso de Manejo de Grupos).
- 30: Supone que la data estará en EXCEL
- 36: Ejemplo: Hoja Excel del Control de Visitantes y de Clientes de Casa de Bolsa para demostrar la funcionalidad.
- 41: Adiestramiento para que sea divulgado.
- 42: Incluye Trabajadores y Relacionados.
- 46: Prèt-â-Porter
- 47: Creación de la Solicitud / Asignación a un Departamento / Control y Seguimiento de la Solicitud (Departamento, Cliente) / Cierre de la Solicitud (Finalización o Cancelación) / Notificación al Cliente

| ID | WBS | Task | Duration | Start | Finish | Predecessors | Total slack | Free slack | Resources | Work |
| --- | --- | --- | --- | --- | --- | --- | --- | --- | --- | --- |
| 51 | 7 | **Solicitudes Organización 1** | 20d | 2004-07-02 | 2004-07-30 | 46 | 0d |  |  | 216h |
| 52 | 7.1 | Kick Off (Definición de Solicitudes) | 1d | 2004-07-02 | 2004-07-05 |  | 0d |  | Jamile Track; Olga Lorenzo | 16h |
| 53 | 7.2 | Preparación de Formas | 3d | 2004-07-05 | 2004-07-08 | 52 | 0d |  | Jamile Track; Olga Lorenzo | 48h |
| 54 | 7.3 | Elaboración de Programas Específicos | 3d | 2004-07-08 | 2004-07-13 | 53 | 0d |  | Jamile Track; Olga Lorenzo | 48h |
| 55 | 7.4 | Pruebas | 1d | 2004-07-13 | 2004-07-14 | 54 | 0d |  | Jamile Track | 8h |
| 56 | 7.5 | Adiestramiento en el Manejo de la Solicitud | 2d | 2004-07-14 | 2004-07-16 | 55 | 0d |  | Jamile Track | 16h |
| 57 | 7.6 | Soporte/Apoyo al Cliente | 10d | 2004-07-16 | 2004-07-30 | 56 | 0d |  | Jamile Track | 80h |
| 58 | 8 | **Solicitudes Organización 2** | 20d | 2004-07-30 | 2004-08-27 | 51 | 344d |  | Jamile Track | 320h |
| 59 | 8.1 | Kick Off (Definición de Solicitudes) | 1d | 2004-07-30 | 2004-08-02 |  | 344d | 0d | Jamile Track | 8h |
| 60 | 8.2 | Preparación de Formas | 3d | 2004-08-02 | 2004-08-05 | 59 | 344d | 0d | Jamile Track | 24h |
| 61 | 8.3 | Elaboración de Programas Específicos | 3d | 2004-08-05 | 2004-08-10 | 60 | 344d | 0d | Jamile Track | 24h |
| 62 | 8.4 | Pruebas | 1d | 2004-08-10 | 2004-08-11 | 61 | 344d | 0d | Jamile Track | 8h |
| 63 | 8.5 | Adiestramiento en el Manejo de la Solicitud | 2d | 2004-08-11 | 2004-08-13 | 62 | 344d | 0d | Jamile Track | 16h |
| 64 | 8.6 | Seguimiento | 10d | 2004-08-13 | 2004-08-27 | 63 | 344d |  | Jamile Track | 80h |
| 65 | 9 | **Solicitudes Organización 3** | 20d | 2004-07-30 | 2004-08-27 | 51 | 0d |  | Olga Lorenzo | 320h |
| 66 | 9.1 | Kick Off (Definición de Solicitudes) | 1d | 2004-07-30 | 2004-08-02 |  | 0d |  | Olga Lorenzo | 8h |
| 67 | 9.2 | Preparación de Formas | 3d | 2004-08-02 | 2004-08-05 | 66 | 0d |  | Olga Lorenzo | 24h |
| 68 | 9.3 | Elaboración de Programas Específicos | 3d | 2004-08-05 | 2004-08-10 | 67 | 0d |  | Olga Lorenzo | 24h |
| 69 | 9.4 | Pruebas | 1d | 2004-08-10 | 2004-08-11 | 68 | 0d |  | Olga Lorenzo | 8h |
| 70 | 9.5 | Adiestramiento en el Manejo de la Solicitud | 2d | 2004-08-11 | 2004-08-13 | 69 | 0d |  | Olga Lorenzo | 16h |
| 71 | 9.6 | Seguimiento | 10d | 2004-08-13 | 2004-08-27 | 70 | 0d |  | Olga Lorenzo | 80h |
| 72 | 10 | **Solicitudes Organización 4** | 20d | 2004-08-27 | 2004-09-24 | 65 | 324d |  | Jamile Track | 320h |
| 73 | 10.1 | Kick Off (Definición de Solicitudes) | 1d | 2004-08-27 | 2004-08-30 |  | 324d | 0d | Jamile Track | 8h |
| 74 | 10.2 | Preparación de Formas | 3d | 2004-08-30 | 2004-09-02 | 73 | 324d | 0d | Jamile Track | 24h |
| 75 | 10.3 | Elaboración de Programas Específicos | 3d | 2004-09-02 | 2004-09-07 | 74 | 324d | 0d | Jamile Track | 24h |
| 76 | 10.4 | Pruebas | 1d | 2004-09-07 | 2004-09-08 | 75 | 324d | 0d | Jamile Track | 8h |
| 77 | 10.5 | Adiestramiento en el Manejo de la Solicitud | 2d | 2004-09-08 | 2004-09-10 | 76 | 324d | 0d | Jamile Track | 16h |
| 78 | 10.6 | Seguimiento | 10d | 2004-09-10 | 2004-09-24 | 77 | 324d |  | Jamile Track | 80h |

Notes:
- 54: Revisadores, Vistas Extendidas Propias, Limpiadores.
- 57: Seguimiento para verificar el uso, problemas, entonación, conocimiento.
- 61: Revisadores, Vistas Extendidas Propias, Limpiadores.
- 64: Seguimiento para verificar el uso, problemas, entonación, conocimiento.
- 68: Revisadores, Vistas Extendidas Propias, Limpiadores.
- 71: Seguimiento para verificar el uso, problemas, entonación, conocimiento.
- 75: Revisadores, Vistas Extendidas Propias, Limpiadores.
- 78: Seguimiento para verificar el uso, problemas, entonación, conocimiento.

| ID | WBS | Task | Duration | Start | Finish | Predecessors | Total slack | Free slack | Resources | Work |
| --- | --- | --- | --- | --- | --- | --- | --- | --- | --- | --- |
| 79 | 11 | **Solicitudes Organización 5** | 20d | 2004-08-27 | 2004-09-24 | 65 | 0d |  | Olga Lorenzo | 160h |
| 80 | 11.1 | Kick Off (Definición de Solicitudes) | 1d | 2004-08-27 | 2004-08-30 |  | 0d |  |  |  |
| 81 | 11.2 | Preparación de Formas | 3d | 2004-08-30 | 2004-09-02 | 80 | 0d |  |  |  |
| 82 | 11.3 | Elaboración de Programas Específicos | 3d | 2004-09-02 | 2004-09-07 | 81 | 0d |  |  |  |
| 83 | 11.4 | Pruebas | 1d | 2004-09-07 | 2004-09-08 | 82 | 0d |  |  |  |
| 84 | 11.5 | Adiestramiento en el Manejo de la Solicitud | 2d | 2004-09-08 | 2004-09-10 | 83 | 0d |  |  |  |
| 85 | 11.6 | Seguimiento | 10d | 2004-09-10 | 2004-09-24 | 84 | 0d |  |  |  |
| 86 | 12 | **Control de Visitantes (Básico)** | 16d | 2004-09-24 | 2004-10-18 | 79 | 0d |  | Jamile Track | 256h |
| 87 | 12.1 | Kick Off | 1d | 2004-09-24 | 2004-09-27 |  | 0d |  | Jamile Track | 8h |
| 88 | 12.2 | Análisis del Proceso de Control de Visitantes | 2d | 2004-09-27 | 2004-09-29 | 87 | 0d |  | Jamile Track | 16h |
| 89 | 12.3 | Diseño del Proceso de Control de Visitantes | 2d | 2004-09-29 | 2004-10-01 | 88 | 0d |  | Jamile Track | 16h |
| 90 | 12.4 | Construcción del Proceso de Control de Visitantes | 5d | 2004-10-01 | 2004-10-08 | 89 | 0d |  | Jamile Track | 40h |
| 91 | 12.5 | Pruebas | 2d | 2004-10-08 | 2004-10-12 | 90 | 0d |  | Jamile Track | 16h |
| 92 | 12.6 | Aceptación | 1d | 2004-10-12 | 2004-10-13 | 91 | 0d |  | Jamile Track | 8h |
| 93 | 12.7 | Adiestramiento Usuarios | 3d | 2004-10-13 | 2004-10-18 | 92 | 0d |  | Jamile Track | 24h |
| 94 | 13 | **Control de Visitantes (Avanzado)** | 19d | 2004-10-18 | 2004-11-12 | 86 | 0d |  | Jamile Track | 304h |
| 95 | 13.1 | Opciones Adicionales | 15d | 2004-10-18 | 2004-11-08 |  | 0d |  | Jamile Track | 120h |
| 96 | 13.2 | Pruebas | 2d | 2004-11-08 | 2004-11-10 | 95 | 0d |  | Jamile Track | 16h |
| 97 | 13.3 | Aceptación | 1d | 2004-11-10 | 2004-11-11 | 96 | 0d |  | Jamile Track | 8h |
| 98 | 13.4 | Adiestramiento Usuarios | 1d | 2004-11-11 | 2004-11-12 | 97 | 0d |  | Jamile Track | 8h |
| 99 | 14 | **Control de Salones y Recursos (Básico)** | 16d | 2004-09-24 | 2004-10-18 | 79 | 194d | 0d | Olga Lorenzo | 256h |
| 100 | 14.1 | Kick Off | 1d | 2004-09-24 | 2004-09-27 |  | 194d | 0d | Olga Lorenzo | 8h |
| 101 | 14.2 | Análisis del Proceso de Control de Visitantes | 2d | 2004-09-27 | 2004-09-29 | 100 | 194d | 0d | Olga Lorenzo | 16h |
| 102 | 14.3 | Diseño del Proceso de Control de Visitantes | 2d | 2004-09-29 | 2004-10-01 | 101 | 194d | 0d | Olga Lorenzo | 16h |
| 103 | 14.4 | Construcción del Proceso de Control de Visitantes | 5d | 2004-10-01 | 2004-10-08 | 102 | 194d | 0d | Olga Lorenzo | 40h |
| 104 | 14.5 | Pruebas | 2d | 2004-10-08 | 2004-10-12 | 103 | 194d | 0d | Olga Lorenzo | 16h |
| 105 | 14.6 | Aceptación | 1d | 2004-10-12 | 2004-10-13 | 104 | 194d | 0d | Olga Lorenzo | 8h |
| 106 | 14.7 | Adiestramiento Usuarios | 3d | 2004-10-13 | 2004-10-18 | 105 | 194d |  | Olga Lorenzo | 24h |

Notes:
- 82: Revisadores, Vistas Extendidas Propias, Limpiadores.
- 85: Seguimiento para verificar el uso, problemas, entonación, conocimiento.
- 95: Interfaz a Cámaras. / Asociar con la persona del Banco que visita. / Mensaje interno avisando al que visita. / Visitas preprogramadas. / Mensajes por emergencias (operación de un familiar).

| ID | WBS | Task | Duration | Start | Finish | Predecessors | Total slack | Free slack | Resources | Work |
| --- | --- | --- | --- | --- | --- | --- | --- | --- | --- | --- |
| 107 | 15 | **Control de Salones y Recursos (Avanzado)** | 24d | 2004-10-18 | 2004-11-19 | 99 | 194d | 0d | Olga Lorenzo | 384h |
| 108 | 15.1 | Opciones Adicionales | 20d | 2004-10-18 | 2004-11-15 |  | 194d | 0d | Olga Lorenzo | 160h |
| 109 | 15.2 | Pruebas | 2d | 2004-11-15 | 2004-11-17 | 108 | 194d | 0d | Olga Lorenzo | 16h |
| 110 | 15.3 | Aceptación | 1d | 2004-11-17 | 2004-11-18 | 109 | 194d | 0d | Olga Lorenzo | 8h |
| 111 | 15.4 | Adiestramiento Usuarios | 1d | 2004-11-18 | 2004-11-19 | 110 | 194d |  | Olga Lorenzo | 8h |
| 112 | 16 | **Manuales y procedimientos (Básico)** | 28d | 2004-11-12 | 2004-12-22 | 94 | 0d |  | Listbeth Rojas | 448h |
| 113 | 16.1 | Kick Off | 2d | 2004-11-12 | 2004-11-16 |  | 0d |  | Listbeth Rojas | 16h |
| 114 | 16.2 | Análisis del Proceso de Manual y Procedimientos | 5d | 2004-11-16 | 2004-11-23 | 113 | 0d |  | Listbeth Rojas | 40h |
| 115 | 16.3 | Diseño del Módulo de Manual y Procedimientos | 5d | 2004-11-23 | 2004-11-30 | 114 | 0d |  | Listbeth Rojas | 40h |
| 116 | 16.4 | Construcción del Módulo de Manuales y Procedimientos | 10d | 2004-11-30 | 2004-12-14 | 115 | 0d |  | Listbeth Rojas | 80h |
| 117 | 16.5 | Pruebas | 2d | 2004-12-14 | 2004-12-16 | 116 | 0d |  | Listbeth Rojas | 16h |
| 118 | 16.6 | Aceptación | 1d | 2004-12-16 | 2004-12-17 | 117 | 0d |  | Listbeth Rojas | 8h |
| 119 | 16.7 | Adiestramiento Usuarios | 3d | 2004-12-17 | 2004-12-22 | 118 | 0d |  | Listbeth Rojas | 24h |
| 120 | 17 | **Manuales y procedimientos (Avanzado)** | 41d | 2004-12-22 | 2005-02-17 | 112 | 0d |  | Listbeth Rojas | 656h |
| 121 | 17.1 | Work Flow y Manejo de Documentos | 15d | 2004-12-22 | 2005-01-12 |  | 0d |  | Listbeth Rojas | 120h |
| 122 | 17.2 | Opciones Adicionales | 20d | 2005-01-12 | 2005-02-09 | 121 | 0d |  | Listbeth Rojas | 160h |
| 123 | 17.3 | Pruebas | 2d | 2005-02-09 | 2005-02-11 | 122 | 0d |  | Listbeth Rojas | 16h |
| 124 | 17.4 | Aceptación | 1d | 2005-02-11 | 2005-02-14 | 123 | 0d |  | Listbeth Rojas | 8h |
| 125 | 17.5 | Adiestramiento Usuarios | 3d | 2005-02-14 | 2005-02-17 | 124 | 0d |  | Listbeth Rojas | 24h |
| 126 | 18 | **Contenidos Departamentales/Organizacionales** | 15d | 2004-11-19 | 2004-12-10 | 107 | 194d | 0d | Jamile Track | 240h |
| 127 | 18.1 | Dept/Org 1 | 5d | 2004-11-19 | 2004-11-26 |  | 194d | 0d | Jamile Track | 40h |
| 128 | 18.2 | Dept/Org 2 | 5d | 2004-11-26 | 2004-12-03 | 127 | 194d | 0d | Jamile Track | 40h |
| 129 | 18.3 | Dept/Org 3 | 5d | 2004-12-03 | 2004-12-10 | 128 | 194d |  | Jamile Track | 40h |
| 130 | 19 | **Acciones y Minutas** | 15d | 2004-12-10 | 2004-12-31 | 126 | 194d | 0d | Olga Lorenzo | 240h |
| 131 | 19.1 | ADC del Módulo de Acciones y Minutas | 15d | 2004-12-10 | 2004-12-31 |  | 194d |  | Olga Lorenzo | 120h |

Notes:
- 108: Manejo de Agendas. / Mensaje interno avisando que la reservación fue realizada. / Cancelaciones.
- 122: Versiones / Plug Ins (EXCEL, WORD, POWER POINT, PDF, AUTOCAD) / Búsquedas Avanzadas / Formas Inteligentes / Relación con el Módulo de Solicitudes / Categorización
- 127: Kick Off / Análisis, Diseño y Construcción / Prueba / Adiestramiento / Se utilizará el Perfil Actualización Contenido (solo actualizar el que tenga el perfil de Actualización + AND mi login) para autorizar la modificación en el campo. AR2-x se agregará un campo con un campo protegido que da la autorización para ver y puede modificar Comunicaciones Corporativas.
- 128: Kick Off / Análisis, Diseño y Construcción / Prueba / Adiestramiento / Se utilizará el Perfil Actualización Contenido (solo actualizar el que tenga el perfil de Actualización + AND mi login) para autorizar la modificación en el campo. AR2-x se agregará un campo con un campo protegido que da la autorización para ver y puede modificar Comunicaciones Corporativas.
- 129: Kick Off / Análisis, Diseño y Construcción / Prueba / Adiestramiento / Se utilizará el Perfil Actualización Contenido (solo actualizar el que tenga el perfil de Actualización + AND mi login) para autorizar la modificación en el campo. AR2-x se agregará un campo con un campo protegido que da la autorización para ver y puede modificar Comunicaciones Corporativas.

| ID | WBS | Task | Duration | Start | Finish | Predecessors | Total slack | Free slack | Resources | Work |
| --- | --- | --- | --- | --- | --- | --- | --- | --- | --- | --- |
| 132 | 20 | **Sala Virtual** | 20d | 2004-12-31 | 2005-01-28 | 130 | 194d | 0d | Olga Lorenzo | 320h |
| 133 | 20.1 | ADC del Módulo de Sala Virtual | 20d | 2004-12-31 | 2005-01-28 |  | 194d |  | Olga Lorenzo | 160h |
| 134 | 21 | **Groupware** | 40d | 2005-01-28 | 2005-03-25 | 132 | 194d |  | Simón Cordido | 640h |
| 135 | 21.1 | Foros de Discusión | 10d | 2005-01-28 | 2005-02-11 |  | 194d | 0d | Simón Cordido | 80h |
| 136 | 21.2 | Chat | 10d | 2005-02-11 | 2005-02-25 | 135 | 194d | 0d | Simón Cordido | 80h |
| 137 | 21.3 | Calendario/Agenda | 10d | 2005-02-25 | 2005-03-11 | 136 | 194d | 0d | Simón Cordido | 80h |
| 138 | 21.4 | Trabajo Colaborativo | 10d | 2005-03-11 | 2005-03-25 | 137 | 194d |  | Simón Cordido | 80h |
| 139 | 22 | **Help Desk** | 60d | 2005-02-17 | 2005-05-12 | 120 | 0d |  | Jamile Track; Olga Lorenzo | 1920h |
| 140 | 22.1 | ADC del Módulo de Help Desk | 3mo | 2005-02-17 | 2005-05-12 |  | 0d |  | Jamile Track; Olga Lorenzo | 960h |
| 141 | 23 | **CRM** | 120d | 2005-05-12 | 2005-10-27 | 139 | 0d |  | Jamile Track; Olga Lorenzo | 3840h |
| 142 | 23.1 | ADC del Módulo de CRM | 6mo | 2005-05-12 | 2005-10-27 |  | 0d |  | Jamile Track; Olga Lorenzo | 1920h |
| 143 | 24 | **E-Learning** | 40d | 2005-10-27 | 2005-12-22 | 141 | 0d |  | Jamile Track; Olga Lorenzo | 1280h |
| 144 | 24.1 | ADC del Módulo de e-Learning | 2mo | 2005-10-27 | 2005-12-22 |  | 0d |  | Jamile Track; Olga Lorenzo | 640h |

Notes:
- 132: Pueden adelantarse algunas actividades como la Cartelera (agregando un recurso o postergando otras actividades).
- 134: Lista Larga, Lista Corta, Evaluación, Selección, Diseño, Procura e Instalación. / Pueden adelantarse algunas actividades (agregando un recurso o postergando otras actividades).
