# PlanPreliminarHertz0604

Schedule from MS Project, 2005-04-06 to 2006-03-07, A marks actual dates.
gm

## Calendars

- Estándar: Mon-Fri 09:00-13:00, 15:00-19:00; Sat-Sun off.

## Resources

| Resource |
| --- |
| GM |
| usuario Funcional |
| Verónica |
| Todos |
| Nelson |
| Metadeveloper |
| Veronica |
| Meatdeveloper |
| Aron |

## Schedule

| ID | WBS | Task | Type | Duration | Start | Finish | Predecessors | Complete | Remaining | Baseline start | Baseline finish | Baseline duration | Total slack | Free slack | Constraint | Resources | Work | Actual work |
| --- | --- | --- | --- | --- | --- | --- | --- | --- | --- | --- | --- | --- | --- | --- | --- | --- | --- | --- |
| 1 | 1 | **Sistema para HERTZ Renta Motor** |  | 240d? | 2005-04-06 A | 2006-03-07 |  | 15% | 203.38d? | 2005-04-08 | 2005-12-30 | 191d? | 0d |  |  |  | 16568h | 2739.4h |
| 2 | 1.1 | Planificación del Proyecto |  | 24d? | 2005-04-19 A | 2005-05-20 A |  | 100% |  | 2005-04-19 | 2005-05-20 | 24d? |  |  | start no earlier than 2005-04-19 | GM | 192h | 192h |
| 3 | 1.2 | **Manejo Requerimientos** |  | 61d? | 2005-04-08 A | 2005-07-01 |  | 77% | 14.19d? | 2005-04-08 | 2005-05-31 | 38d? | 177d |  |  |  | 592h | 357h |
| 4 | 1.2.1 | Levantamiento de especificaciones |  | 21d | 2005-04-08 A | 2005-05-06 A |  | 100% |  | 2005-04-08 | 2005-05-06 | 21d |  |  | finish no earlier than 2005-05-06 | GM | 168h | 168h |
| 5 | 1.2.2 | **Análisis** |  | 57d? | 2005-04-14 A | 2005-07-01 |  | 47% | 30d? | 2005-04-14 | 2005-05-31 | 34d? | 177d |  |  |  | 400h | 165h |
| 6 | 1.2.2.1 | Plataforma |  | 3d? | 2005-04-14 A | 2005-04-18 A |  | 100% |  | 2005-04-14 | 2005-04-18 | 3d? |  |  | start no earlier than 2005-04-14 | GM | 24h | 24h |
| 7 | 1.2.2.2 | **Aplicación** |  | 31d? | 2005-05-20 A | 2005-07-01 |  | 38% | 19.38d? | 2005-05-09 | 2005-05-31 | 17d? | 177d |  |  | GM | 376h | 141h |
| 8 | 1.2.2.2.1 | Elaboracion Documento Especificaciones y Matríz Requerimiento |  | 3d? | 2005-05-20 A | 2005-05-24 A |  | 100% |  | 2005-05-12 | 2005-05-16 | 3d? |  |  | start no earlier than 2005-05-12 | GM | 24h | 24h |
| 9 | 1.2.2.2.2 | Entrega Especificaciones | milestone | 0d | 2005-05-25 A | 2005-05-25 A | 8 | 100% |  |  |  |  |  |  | start no earlier than 2005-05-25 |  |  |  |
| 10 | 1.2.2.2.3 | Aprobación de parte usuario |  | 3d? | 2005-05-25 A | 2005-05-27 A | 9 | 100% |  | 2005-05-17 | 2005-05-19 | 3d? |  |  |  | usuario Funcional | 24h | 24h |
| 11 | 1.2.2.2.4 | Elaboración Plan pruebas |  | 7d? | 2005-06-20 | 2005-06-28 |  |  |  | 2005-05-20 | 2005-05-24 | 3d? | 177d | 0d | start no earlier than 2005-06-20 | GM | 56h |  |
| 12 | 1.2.2.2.5 | Aprobacion Plan Pruebas |  | 3d? | 2005-06-29 | 2005-07-01 | 11 |  |  | 2005-05-25 | 2005-05-27 | 3d? | 177d | 0d |  | usuario Funcional | 24h |  |
| 13 | 1.2.2.2.6 | Documento con Plan de Pruebas | milestone | 0d? | 2005-07-01 | 2005-07-01 | 12 |  |  | 2005-05-27 | 2005-05-27 | 0d? | 177d |  | start no earlier than 2005-04-15 |  |  |  |
| 14 | 1.2.3 | Análisis y estrategia de trabajo conel grupo |  | 3d? | 2005-05-02 A | 2005-05-04 A |  | 100% |  | 2005-05-02 | 2005-05-04 | 3d? |  |  | finish no earlier than 2005-05-04 | Todos | 24h | 24h |
| 15 | 1.3 | **Diseño Aplicación** |  | 50d? | 2005-05-17 A | 2005-07-25 |  | 75% | 12.7d? | 2005-05-17 | 2005-07-01 | 34d? | 161d |  |  |  | 1088h | 718.4h |
| 16 | 1.3.1 | Modelo Lógico BD |  | 7d? | 2005-05-17 A | 2005-05-31 A | 8 | 100% |  | 2005-05-17 | 2005-05-19 | 3d? |  |  | start no earlier than 2005-05-04 | GM | 56h | 56h |
| 17 | 1.3.2 | Modelo Lógico BD | milestone | 0d? | 2005-06-27 | 2005-06-27 | 16 |  |  |  |  |  | 182d |  | start no earlier than 2005-06-27 |  |  |  |
| 18 | 1.3.3 | Modelo Físico BD |  | 10d? | 2005-05-25 A | 2005-06-10 A | 17 | 100% |  | 2005-05-20 | 2005-05-26 | 4.93d? |  |  | finish no earlier than 2005-05-11 | Todos | 80h | 80h |
| 19 | 1.3.4 | Modelo de Integración |  | 5d? | 2005-05-17 A | 2005-05-26 A | 8 | 100% |  | 2005-05-17 | 2005-05-23 | 5d? |  |  |  | Nelson | 40h | 40h |
| 20 | 1.3.5 | Prediseño de Aplicación |  | 5d? | 2005-05-30 A | 2005-06-03 |  | 80% | 1d? | 2005-05-30 | 2005-06-03 | 5d? | 26d | 0d | start no earlier than 2005-05-04 | GM [60%]; Verónica [20%]; Nelson [20%]; Metadeveloper [20%] | 48h | 38.4h |
| 21 | 1.3.6 | Prototipo aplicación |  | 29d? | 2005-06-06 A | 2005-07-14 | 20 | 72% | 8d? | 2005-06-06 | 2005-07-01 | 20d? | 5d | 0d | finish no earlier than 2005-07-14 | Verónica; Nelson; Metadeveloper | 696h | 504h |
| 22 | 1.3.7 | Prototipo Aplicación | milestone | 0d | 2005-07-14 | 2005-07-14 |  |  |  | 2005-07-01 | 2005-07-01 | 0d | 169d |  | start no earlier than 2005-07-14 |  |  |  |
| 23 | 1.3.8 | Entonación Prototipo |  | 7d? | 2005-07-15 | 2005-07-25 |  |  |  | 2005-06-02 | 2005-06-06 | 3d? | 161d |  | start no earlier than 2005-07-15 | Verónica; Nelson; Metadeveloper | 168h |  |
| 24 | 1.4 | **Carga Data Aplicación** |  | 127d? | 2005-06-15 A | 2005-12-08 |  | 43% | 73.03d? | 2005-05-30 | 2005-12-29 | 154d? | 63d |  |  |  | 344h | 272h |
| 25 | 1.4.1 | Análisis |  | 10d | 2005-06-15 A | 2005-06-28 A |  | 100% |  | 2005-05-30 | 2005-06-10 | 10d |  |  | start no earlier than 2005-06-15 | GM; usuario Funcional | 160h | 160h |

Notes:
- 19: Integracion con otros sistemas. Esquema de actualizacion de la información a nivel nacional. Integracion con Directorio Relacionados y Directorio de Trabajadores

| ID | WBS | Task | Type | Duration | Start | Finish | Predecessors | Complete | Baseline start | Baseline finish | Baseline duration | Total slack | Free slack | Constraint | Resources | Work | Actual work |
| --- | --- | --- | --- | --- | --- | --- | --- | --- | --- | --- | --- | --- | --- | --- | --- | --- | --- |
| 26 | 1.4.2 | **Preparación** |  | 7d? | 2005-06-29 A | 2005-07-07 A | 25 | 100% | 2005-06-13 | 2005-09-23 | 75d? |  |  |  |  | 112h | 112h |
| 27 | 1.4.2.1 | Estrategia |  | 7d? | 2005-06-29 A | 2005-07-07 A |  | 100% | 2005-06-13 | 2005-06-21 | 7d? |  |  | start no earlier than 2005-06-09 | GM; usuario Funcional | 112h | 112h |
| 28 | 1.4.2.2 | Documento con estrategia de Carga Datos | milestone | 0d? | 2005-07-07 A | 2005-07-07 A |  | 100% |  |  |  |  |  | start no earlier than 2005-07-07 |  |  |  |
| 29 | 1.4.3 | Data |  | 20d? | 2005-07-11 | 2005-08-05 |  |  | 2005-09-01 | 2005-09-23 | 17d? | 152d |  | start no earlier than 2005-07-11 |  |  |  |
| 30 | 1.4.4 | Carga adicional como baseline |  | 3d | 2005-12-06 | 2005-12-08 |  |  | 2005-12-06 | 2005-12-08 | 3d | 63d |  | start no earlier than 2005-12-06 | Meatdeveloper; GM; usuario Funcional | 72h |  |
| 31 | 1.5 | **Configuración Aplicación** |  | 3d? | 2005-05-02 A | 2005-05-04 A |  | 100% | 2005-05-02 | 2005-05-04 | 3d? |  |  |  |  | 24h | 24h |
| 32 | 1.5.1 | Ambiente N2C |  | 3d? | 2005-05-02 A | 2005-05-04 A |  | 100% | 2005-05-02 | 2005-05-04 | 3d? |  |  | start no earlier than 2005-05-02 | Veronica | 24h | 24h |
| 33 | 1.6 | **Desarrollo Aplicación** |  | 220d? | 2005-04-06 | 2006-02-07 |  |  | 2005-07-01 | 2005-08-19 | 36d? | 20d |  |  |  | 2840h |  |
| 34 | 1.6.1 | **Módulo Reservaciones** |  | 75d? | 2005-07-18 | 2005-10-28 |  |  | 2005-07-01 | 2005-08-18 | 35d? | 87d |  |  | Verónica | 600h |  |
| 35 | 1.6.1.1 | Desarrollo |  | 60d? | 2005-08-08 | 2005-10-28 |  |  | 2005-07-01 | 2005-08-18 | 35d? | 72d | 0d | start no earlier than 2005-08-08 |  |  |  |
| 36 | 1.6.1.2 | **Ingreso de reservaciones** |  | 14d? | 2005-07-18 | 2005-08-04 |  |  |  |  |  | 138d | 0d |  |  |  |  |
| 37 | 1.6.1.2.1 | Ingreso de campos de reservaciones |  | 4d? | 2005-07-18 | 2005-07-21 |  |  |  |  |  | 142d | 0d | start no earlier than 2005-07-18 |  |  |  |
| 38 | 1.6.1.2.2 | Ingreso Cliente Natural y Jurídico |  | 2d? | 2005-07-22 | 2005-07-25 | 37 |  |  |  |  | 142d | 0d |  |  |  |  |
| 39 | 1.6.1.2.3 | Cálculo de Montos en función de servicios y tarifas |  | 3d? | 2005-07-26 | 2005-07-28 | 38 |  |  |  |  | 142d | 0d |  |  |  |  |
| 40 | 1.6.1.2.4 | Mostrar grupos y subgrupos disponibles |  | 1d? | 2005-07-29 | 2005-07-29 | 39 |  |  |  |  | 142d |  |  |  |  |  |
| 41 | 1.6.1.2.5 | Manejo de Versiones |  | 1d? | 2005-07-29 | 2005-07-29 |  |  |  |  |  | 138d | 0d | start no earlier than 2005-07-29 |  |  |  |
| 42 | 1.6.1.2.6 | Link P'agina IVSS |  | 1d? | 2005-08-01 | 2005-08-01 | 41 |  |  |  |  | 138d | 0d |  |  |  |  |
| 43 | 1.6.1.2.7 | Prepago |  | 3d? | 2005-08-02 | 2005-08-04 | 42 |  |  |  |  | 138d |  |  |  |  |  |
| 44 | 1.6.1.3 | Ingreso Tarifas |  | 1d? | 2005-08-05 | 2005-08-05 | 36 |  |  |  |  | 138d | 0d |  |  |  |  |
| 45 | 1.6.1.4 | Ingreso Lista Precios (Ajustar) |  | 1d? | 2005-08-08 | 2005-08-08 | 44 |  |  |  |  | 138d | 0d |  |  |  |  |
| 46 | 1.6.1.5 | Convenio |  | 3d? | 2005-08-09 | 2005-08-11 | 45 |  |  |  |  | 138d | 0d |  |  |  |  |
| 47 | 1.6.1.6 | Programa Descuento |  | 2d? | 2005-08-12 | 2005-08-15 | 46 |  |  |  |  | 138d | 0d | start no earlier than 2005-07-14 |  |  |  |
| 48 | 1.6.1.7 | Configuración Listas Precio a Renta Motor |  | 2d? | 2005-08-16 | 2005-08-17 | 47 |  |  |  |  | 138d | 0d |  |  |  |  |
| 49 | 1.6.1.8 | Ingreso Servicios e Impuestos |  | 1d? | 2005-08-18 | 2005-08-18 | 48 |  |  |  |  | 138d | 0d |  |  |  |  |
| 50 | 1.6.1.9 | Cáclulo Tarifas por Equilibrio |  | 5d? | 2005-08-19 | 2005-08-25 | 49 |  |  |  |  | 138d |  |  |  |  |  |

Notes:
- 30: Es el base line antes de comenzar con el de producci'on
- 32: Se crea la aplicacion en N2c, se crean las tablas de las bases de datos y se configura el ambiente necesario para los desarrolladores
- 37: Incluye validaciones de clientes por existencia, por record, tipo. Validción de convenio, de tarifas. Validación de disponibilidad de vehículo. Ingreso de Predespacho. De pagos..Cálculo de los montos

| ID | WBS | Task | Type | Duration | Start | Finish | Predecessors | Baseline start | Baseline finish | Baseline duration | Total slack | Free slack | Constraint | Resources | Work |
| --- | --- | --- | --- | --- | --- | --- | --- | --- | --- | --- | --- | --- | --- | --- | --- |
| 51 | 1.6.2 | **Módulo Gestión Alquiler** |  | 148d? | 2005-07-15 | 2006-02-07 | 21 | 2005-07-04 | 2005-08-19 | 35d? | 0d |  |  | Nelson | 1184h |
| 52 | 1.6.2.1 | Desarrollo |  | 60d | 2005-08-08 | 2005-10-28 |  | 2005-07-04 | 2005-08-19 | 35d | 72d |  | start no earlier than 2005-08-08 |  |  |
| 53 | 1.6.2.2 | **Contrato** |  | 9d? | 2005-07-18 | 2005-07-28 |  |  |  |  | 4d |  |  |  |  |
| 54 | 1.6.2.2.1 | **Ingreso** |  | 5d? | 2005-07-18 | 2005-07-22 |  |  |  |  | 4d | 0d |  |  |  |
| 55 | 1.6.2.2.1.1 | Ingreso |  | 5d? | 2005-07-18 | 2005-07-22 | 57 |  |  |  | 138d |  |  |  |  |
| 56 | 1.6.2.2.1.2 | Validación clientes&Ingreso Clientes | milestone | 0d? | 2005-07-18 | 2005-07-18 |  |  |  |  | 4d |  | start no earlier than 2005-07-18 |  |  |
| 57 | 1.6.2.2.1.3 | Validacion de Convenios | milestone | 0d? | 2005-07-18 | 2005-07-18 |  |  |  |  | 138d | 0d | start no earlier than 2005-07-18 |  |  |
| 58 | 1.6.2.2.2 | **Cierre** |  | 4d? | 2005-07-25 | 2005-07-28 |  |  |  |  | 138d |  |  |  |  |
| 59 | 1.6.2.2.2.1 | Ingreso Orden 19 Ptos |  | 2d? | 2005-07-25 | 2005-07-26 | 54 |  |  |  | 138d | 0d | start no earlier than 2005-07-22 |  |  |
| 60 | 1.6.2.2.2.2 | Pagos |  | 2d? | 2005-07-27 | 2005-07-28 | 59 |  |  |  | 138d |  |  |  |  |
| 61 | 1.6.2.2.3 | **Cambios Contratos** |  | 4d? | 2005-07-22 | 2005-07-27 | 56 |  |  |  | 0d |  |  |  |  |
| 62 | 1.6.2.2.3.1 | Upgrade |  | 1d? | 2005-07-22 | 2005-07-22 |  |  |  |  | 0d |  | start no earlier than 2005-07-22 |  |  |
| 63 | 1.6.2.2.3.2 | Cambio vehiculo por gusto |  | 1d? | 2005-07-25 | 2005-07-25 | 62 |  |  |  | 0d |  |  |  |  |
| 64 | 1.6.2.2.3.3 | Cambio Vehiculo por Falla |  | 1d? | 2005-07-26 | 2005-07-26 | 63 |  |  |  | 0d |  |  |  |  |
| 65 | 1.6.2.2.3.4 | Extensión |  | 1d? | 2005-07-27 | 2005-07-27 | 64 |  |  |  | 0d |  |  |  |  |
| 66 | 1.6.2.3 | Ingreso Estaciones |  | 1d? | 2005-07-28 | 2005-07-28 | 61 |  |  |  | 0d |  |  |  |  |
| 67 | 1.6.2.4 | Preingreso Flota |  | 16d? | 2005-07-29 | 2006-02-02 | 66 |  |  |  | 0d |  | start no earlier than 2005-01-24 |  |  |
| 68 | 1.6.2.5 | Ingreso Certificado Póliza |  | 1d? | 2006-02-03 | 2006-02-03 | 67 |  |  |  | 0d |  |  |  |  |
| 69 | 1.6.2.6 | Ingreso Asignación/solicitud |  | 1d? | 2006-02-06 | 2006-02-06 | 68 |  |  |  | 0d |  |  |  |  |
| 70 | 1.6.2.7 | Ingreso traslado y Solicitud |  | 1d? | 2006-02-07 | 2006-02-07 | 69 |  |  |  | 0d |  |  |  |  |
| 71 | 1.6.2.8 | **Facturación** |  | 12d? | 2005-08-04 | 2005-08-19 |  |  |  |  | 122d |  |  |  |  |
| 72 | 1.6.2.8.1 | Facturación por Adelantado |  | 5d? | 2005-08-04 | 2005-08-10 |  |  |  |  | 122d | 0d | start no earlier than 2005-08-04 |  |  |
| 73 | 1.6.2.8.2 | Facturación Alquiler |  | 4d? | 2005-08-11 | 2005-08-16 | 72 |  |  |  | 122d | 0d |  |  |  |
| 74 | 1.6.2.8.3 | **Facturación por Siniestro** |  | 3d? | 2005-08-17 | 2005-08-19 | 73 |  |  |  | 122d |  |  |  |  |
| 75 | 1.6.2.8.3.1 | Facturación por Siniestro |  | 3d? | 2005-08-17 | 2005-08-19 |  |  |  |  | 122d |  |  |  |  |
| 76 | 1.6.2.8.3.2 | Consulta de Productos alta Rotacion | milestone | 0d? | 2005-08-17 | 2005-08-17 |  |  |  |  | 125d |  | start no earlier than 2005-08-17 |  |  |
| 77 | 1.6.2.9 | Pruebas Unitarias |  | 60d? | 2005-07-15 | 2005-10-06 |  | 2005-07-05 | 2005-08-15 | 30d? | 88d |  | start no earlier than 2005-07-05 |  |  |

| ID | WBS | Task | Type | Duration | Start | Finish | Predecessors | Baseline start | Baseline finish | Baseline duration | Total slack | Free slack | Constraint | Resources | Work |
| --- | --- | --- | --- | --- | --- | --- | --- | --- | --- | --- | --- | --- | --- | --- | --- |
| 78 | 1.6.3 | **Módulo Mantenimiento Flota** |  | 132d? | 2005-04-06 | 2005-10-06 |  | 2005-07-04 | 2005-08-19 | 35d? | 108d |  |  | Metadeveloper | 1056h |
| 79 | 1.6.3.1 | **Ingreso Orden lavado/combustible** |  | 79d? | 2005-04-06 | 2005-07-25 |  |  |  |  | 161d |  |  |  |  |
| 80 | 1.6.3.1.1 | Ingreso orden asociada a OT |  | 2d? | 2005-07-18 | 2005-07-19 |  |  |  |  | 165d |  | start no earlier than 2005-07-18 |  |  |
| 81 | 1.6.3.1.2 | Ingreso OlyC no asociada a ninguna orden | milestone | 0d? | 2005-07-18 | 2005-07-18 |  |  |  |  | 164d | 2d | start no earlier than 2005-07-18 |  |  |
| 82 | 1.6.3.1.3 | Totalizar costo de Mano Obra de Lavado OT si está asociada |  | 1d? | 2005-07-19 | 2005-07-19 |  |  |  |  | 165d |  | start no earlier than 2005-07-19 |  |  |
| 83 | 1.6.3.1.4 | Agregar costo por combustible a la OT si esta asociada |  | 1d? | 2005-07-19 | 2005-07-19 |  |  |  |  | 165d |  | start no earlier than 2005-07-19 |  |  |
| 84 | 1.6.3.1.5 | Actualizar Kms. en UNIDAD y OT si esta asociada |  | 1d? | 2005-07-19 | 2005-07-19 |  |  |  |  | 165d |  | start no earlier than 2005-07-19 |  |  |
| 85 | 1.6.3.1.6 | **Ingreso Orden Trabajo** |  | 4d? | 2005-07-20 | 2005-07-25 |  |  |  |  | 161d |  |  |  |  |
| 86 | 1.6.3.1.6.1 | Diseño pagina |  | 1d? | 2005-07-20 | 2005-07-20 | 81 |  |  |  | 162d | 0d | start no earlier than 2005-07-20 |  |  |
| 87 | 1.6.3.1.6.2 | Validaciones y actualizaciones |  | 3d? | 2005-07-21 | 2005-07-25 | 86 |  |  |  | 161d |  |  |  |  |
| 88 | 1.6.3.1.7 | Vista extendida de OT agregar Servicios |  | 1d? | 2005-04-06 | 2005-04-06 |  |  |  |  | 239d |  |  |  |  |
| 89 | 1.6.3.1.8 | Ingreso Tipo Productos |  | 1d? | 2005-04-06 | 2005-04-06 |  |  |  |  | 239d |  |  |  |  |
| 90 | 1.6.3.1.9 | Ingreso Orden Salida Producto |  | 1d? | 2005-04-06 | 2005-04-06 |  |  |  |  | 239d |  |  |  |  |
| 91 | 1.6.3.1.10 | Ingreso Pedidos |  | 1d? | 2005-04-06 | 2005-04-06 |  |  |  |  | 239d |  |  |  |  |
| 92 | 1.6.3.1.11 | Ingreso Solicitud Pedido |  | 1d? | 2005-04-06 | 2005-04-06 |  |  |  |  | 239d |  |  |  |  |
| 93 | 1.6.3.2 | Pruebas Unitarias |  | 60d? | 2005-07-15 | 2005-10-06 | 21 | 2005-07-05 | 2005-08-15 | 30d? | 108d |  | start no earlier than 2005-07-05 |  |  |
| 94 | 1.6.4 | Aplicación HERTZ sin integracion | milestone | 0d? | 2005-09-26 | 2005-09-26 |  | 2005-08-19 | 2005-08-19 | 0d? | 117d |  | start no earlier than 2005-09-26 |  |  |
| 95 | 1.7 | **Integración con otros sistemas** |  | 20d? | 2005-10-31 | 2005-11-25 | 35 | 2005-08-19 | 2005-11-10 | 60d? | 72d |  |  | Veronica | 160h |
| 96 | 1.7.1 | Sistema Digitilización |  | 20d? | 2005-10-31 | 2005-11-25 |  |  |  |  | 72d |  | start no earlier than 2005-09-26 |  |  |
| 97 | 1.7.2 | Sistema Satelital |  | 10d? | 2005-10-31 | 2005-11-11 |  |  |  |  | 82d |  | start no earlier than 2005-09-26 |  |  |
| 98 | 1.7.3 | Página WEB Hertz Renta Motor |  | 15d? | 2005-10-31 | 2005-11-18 |  |  |  |  | 77d |  | start no earlier than 2005-10-10 |  |  |
| 99 | 1.8 | WebServices para sincronizacion Estaciones y CCS |  | 20d? | 2006-02-08 | 2006-03-07 | 51 | 2005-08-22 | 2005-08-22 | 1d? | 0d |  | start no earlier than 2005-10-31 | Nelson | 160h |
| 100 | 1.9 | Documentación de Procesos Génesis | milestone | 0d? | 2005-11-03 | 2005-11-03 |  |  |  |  | 89d |  | start no earlier than 2005-11-03 |  |  |
| 101 | 1.10 | **Pruebas** |  | 20d? | 2005-10-31 | 2005-11-25 |  | 2005-08-22 | 2005-09-28 | 28d? | 72d |  |  |  | 160h |
| 102 | 1.10.1 | Funcionalidad |  | 20d? | 2005-10-31 | 2005-11-25 |  | 2005-08-22 | 2005-09-02 | 10d? | 72d |  | start no earlier than 2005-10-31 | usuario Funcional | 160h |

Notes:
- 94: En Caracas y una agencia Piloto sin integracion
- 95: Interfaz
- 102: Pruebas con el usuario. Incluye pruebas en la estación piloto, más las de Caracas, más la de los otros sistemas

| ID | WBS | Task | Type | Duration | Start | Finish | Predecessors | Complete | Remaining | Baseline start | Baseline finish | Baseline duration | Total slack | Free slack | Constraint | Resources | Work | Actual work |
| --- | --- | --- | --- | --- | --- | --- | --- | --- | --- | --- | --- | --- | --- | --- | --- | --- | --- | --- |
| 103 | 1.11 | **Implantación** |  | 45d? | 2005-10-31 | 2005-12-30 |  |  |  | 2005-08-16 | 2005-12-29 | 98d? | 47d |  |  | Verónica; Nelson; Aron | 1880h |  |
| 104 | 1.11.1 | **Ambiente Desarrollo** |  | 25d? | 2005-10-31 | 2005-12-02 |  |  |  |  |  |  | 67d |  |  |  |  |  |
| 105 | 1.11.1.1 | Crear Aplicaciones y tablas de N2C en desarrollo |  | 5d? | 2005-10-31 | 2005-11-04 |  |  |  |  |  |  | 67d | 0d | start no earlier than 2005-10-31 |  |  |  |
| 106 | 1.11.1.2 | Carga de data historica |  | 10d? | 2005-11-07 | 2005-11-18 | 105 |  |  |  |  |  | 67d | 0d | start no earlier than 2005-09-12 |  |  |  |
| 107 | 1.11.1.3 | Pruebas Estación Piloto |  | 10d? | 2005-11-21 | 2005-12-02 | 106 |  |  | 2005-08-16 | 2005-08-19 | 4d? | 67d | 0d | start no earlier than 2005-09-23 |  |  |  |
| 108 | 1.11.1.4 | Certificación de pruebas | milestone | 0d? | 2005-12-02 | 2005-12-02 | 107 |  |  |  |  |  | 67d |  | start no earlier than 2005-11-25 |  |  |  |
| 109 | 1.11.2 | **Operacionalización** |  | 25d? | 2005-11-28 | 2005-12-30 |  |  |  | 2005-12-07 | 2005-12-29 | 17d? | 47d |  |  | Verónica; Nelson; Aron; Meatdeveloper | 800h |  |
| 110 | 1.11.2.1 | Crear Aplicaciones y tablas de N2C en porduccion |  | 3d? | 2005-12-05 | 2005-12-07 |  |  |  |  |  |  | 54d | 0d | start no earlier than 2005-12-05 |  |  |  |
| 111 | 1.11.2.2 | Carga Data Historica |  | 10d | 2005-12-08 | 2005-12-21 | 110 |  |  |  |  |  | 54d |  |  |  |  |  |
| 112 | 1.11.2.3 | Pase de programas a Producción |  | 1d? | 2005-11-28 | 2005-11-28 |  |  |  |  |  |  | 71d |  | start no earlier than 2005-11-28 |  |  |  |
| 113 | 1.11.2.4 | Estaciones |  | 15d | 2005-12-12 | 2005-12-30 |  |  |  | 2005-12-09 | 2005-12-29 | 15d | 47d |  | start no earlier than 2005-12-12 |  |  |  |
| 114 | 1.11.2.5 | Prueba Corporacion |  | 7d? | 2005-12-05 | 2005-12-13 | 116 |  |  | 2005-12-07 | 2005-12-08 | 2d? | 60d |  | start no earlier than 2005-11-14 |  |  |  |
| 115 | 1.12 | Documentación |  | 162d? | 2005-04-11 A | 2005-11-22 |  | 20% | 129.6d? | 2005-04-11 | 2005-11-22 | 162d? | 75d |  | start no earlier than 2005-04-11 | Verónica; Nelson; Meatdeveloper; GM | 5184h | 1036.8h |
| 116 | 1.13 | Adiestramiento |  | 10d? | 2005-11-21 | 2005-12-02 |  |  |  | 2005-11-14 | 2005-11-18 | 5d? | 60d | 0d | start no earlier than 2005-11-21 | GM; usuario Funcional | 160h |  |
| 117 | 1.14 | Manejo Cambio |  | 110d? | 2005-08-01 | 2005-12-30 |  |  |  | 2005-08-01 | 2005-12-30 | 110d? | 47d |  | finish no earlier than 2005-12-30 | GM; usuario Funcional | 1760h |  |
| 118 | 1.15 | Control y Seguimiento |  | 174d? | 2005-05-03 A | 2005-12-30 |  | 10% | 156.6d? | 2005-05-03 | 2005-12-30 | 174d? | 47d |  | finish no earlier than 2005-12-30 | GM | 1392h | 139.2h |
| 119 | 1.16 | **PostImplantación** |  | 22d? | 2005-12-08 | 2006-01-06 |  |  |  | 2005-12-08 | 2005-12-30 | 17d? | 42d |  |  |  | 632h |  |
| 120 | 1.16.1 | Monitoreo |  | 13d? | 2005-12-14 | 2005-12-30 |  |  |  | 2005-12-08 | 2005-12-30 | 17d? | 47d |  | start no earlier than 2005-12-14 | usuario Funcional | 104h |  |
| 121 | 1.16.2 | Soporte |  | 22d? | 2005-12-08 | 2006-01-06 |  |  |  | 2005-12-08 | 2005-12-30 | 17d? | 42d |  | finish no earlier than 2006-01-06 | Verónica; Meatdeveloper; Nelson | 528h |  |

Notes:
- 113: Validar fecha critica para puesta en produccion en las agencias..Esto puede implicar viajes a las áreas
- 114: Pruebas en mabiente de producción
- 116: Incluye adiestrar al Help Desk
