# Proyecto CRM - Corporacion Union

Schedule from MS Project, 2005-04-01 to 2005-09-09.

## Calendars

- Estándar: Mon-Fri 08:00-12:00, 13:00-17:00; Sat-Sun off. Exceptions (off unless hours are given): 2005-04-19, 2005-06-24, 2005-07-05.

## Resources

| Resource |
| --- |
| Corp. Union |
| Listbeth |
| Olga |
| Loredana |
| Gaby |
| Agustín |
| Valmore |
| Félix |

## Schedule

| ID | WBS | Task | Type | Duration | Start | Finish | Predecessors | Total slack | Free slack | Constraint | Resources | Work |
| --- | --- | --- | --- | --- | --- | --- | --- | --- | --- | --- | --- | --- |
| 1 | 1 | **Proyecto Web Site LagunaMar** |  | 113d | 2005-04-01 | 2005-09-09 |  | 0d |  |  |  | 4440.29h |
| 2 | 1.1 | **Inicio** |  | 1d | 2005-04-01 | 2005-04-01 |  | 112d |  |  |  | 32h |
| 3 | 1.1.1 | Reunión de Arranque (kickoff) |  | 1d | 2005-04-01 | 2005-04-01 |  | 112d |  |  | Corp. Union; Listbeth | 16h |
| 4 | 1.1.2 | Definición del equipo de trabajo |  | 1d | 2005-04-01 | 2005-04-01 |  | 112d |  |  | Listbeth; Corp. Union | 16h |
| 5 | 1.2 | **Levantamiento de Información** |  | 43d | 2005-04-04 | 2005-06-03 |  | 41d |  |  |  | 1164h |
| 6 | 1.2.1 | **Especificación de Requerimientos** |  | 34d | 2005-04-04 | 2005-05-20 |  | 41d |  |  |  | 960h |
| 7 | 1.2.1.1 | Presentación Gerencia de Requerimientos |  | 1d | 2005-04-07 | 2005-04-07 |  | 108d |  | start no earlier than 2005-04-07 | Corp. Union; Listbeth; Olga | 24h |
| 8 | 1.2.1.2 | Preparación material para lev. de requerimientos |  | 2d | 2005-04-08 | 2005-04-11 |  | 106d |  | start no earlier than 2005-04-08 | Listbeth | 16h |
| 9 | 1.2.1.3 | **Tiempo Compartido** |  | 16d | 2005-04-12 | 2005-05-04 |  | 90d |  |  |  | 160h |
| 10 | 1.2.1.3.1 | Sesión de Trabajo # 1 |  | 1d | 2005-04-12 | 2005-04-12 |  | 105d |  | start no earlier than 2005-04-12 | Corp. Union; Olga; Listbeth | 24h |
| 11 | 1.2.1.3.2 | Sesión de Trabajo # 2 |  | 1d | 2005-04-13 | 2005-04-13 |  | 104d |  | start no earlier than 2005-04-13 | Corp. Union; Olga; Listbeth | 24h |
| 12 | 1.2.1.3.3 | Sesión de Trabajo # 3 |  | 1d | 2005-04-20 | 2005-04-20 |  | 100d |  | start no earlier than 2005-04-20 | Corp. Union; Olga; Listbeth | 24h |
| 13 | 1.2.1.3.4 | Elaboración del Informe Esp. de Req. y Matriz de Req. V1 |  | 6d | 2005-04-20 | 2005-04-27 |  | 90d | 0d | start no earlier than 2005-04-20 | Listbeth | 48h |
| 14 | 1.2.1.3.5 | Entrega al Equipo de Proyecto para su revisión | milestone | 0d | 2005-04-27 | 2005-04-27 | 13 | 90d | 0d |  | Listbeth |  |
| 15 | 1.2.1.3.6 | Revisión por parte del Equipo de Proyecto |  | 3d | 2005-04-28 | 2005-05-02 | 14 | 90d | 0d |  | Corp. Union | 24h |
| 16 | 1.2.1.3.7 | Ajustes al Informe Especificación de Requerimientos V1 |  | 2d | 2005-05-03 | 2005-05-04 | 15 | 90d |  |  | Listbeth | 16h |
| 17 | 1.2.1.4 | **Hotel** |  | 26d | 2005-04-13 | 2005-05-19 |  | 79d |  |  |  | 360h |
| 18 | 1.2.1.4.1 | Analisis preliminar de Req. Hotel |  | 6d | 2005-04-13 | 2005-04-21 |  | 99d |  | start no earlier than 2005-04-13 | Corp. Union; Listbeth; Olga | 144h |
| 19 | 1.2.1.4.2 | Visita a MLM - Sesión de Trabajo # 1 |  | 2d | 2005-05-05 | 2005-05-06 |  | 79d | 0d | start no earlier than 2005-05-05 | Corp. Union; Listbeth; Gaby | 48h |
| 20 | 1.2.1.4.3 | Análisis y Definición de Requerimientos |  | 6d | 2005-05-09 | 2005-05-16 | 19 | 79d | 0d |  | Listbeth; Gaby; Agustín | 144h |
| 21 | 1.2.1.4.4 | Actualizac. del Informe Req. del Hotel |  | 3d | 2005-05-17 | 2005-05-19 | 20 | 79d |  |  | Listbeth | 24h |
| 22 | 1.2.1.5 | **Página Web** |  | 34d | 2005-04-04 | 2005-05-20 |  | 41d |  |  |  | 400h |
| 23 | 1.2.1.5.1 | Definición Objetivos de Mercadeo |  | 5d | 2005-04-04 | 2005-04-08 |  | 107d |  | start no earlier than 2005-04-04 | Corp. Union; Valmore | 80h |
| 24 | 1.2.1.5.2 | Definición de la Estructura y Diseño del Site |  | 10d | 2005-05-09 | 2005-05-20 |  | 17d | 0d | start no earlier than 2005-05-09 | Félix; Listbeth; Agustín; Corp. Union | 320h |
| 25 | 1.2.1.5.3 | Entrega Prototipo | milestone | 0d | 2005-05-20 | 2005-05-20 | 24 | 78d |  |  | Listbeth |  |
| 26 | 1.2.2 | Actualización Final Documento y Matriz de Requerimientos V2 |  | 3d | 2005-05-23 | 2005-05-25 | 24 | 17d | 0d |  | Listbeth [50%]; Agustín [50%] | 20h |
| 27 | 1.2.3 | Entrega de Especificación de Requerimientos para aprobación | milestone | 0d | 2005-05-25 | 2005-05-25 | 26 | 17d | 0d |  | Listbeth |  |
| 28 | 1.2.4 | Revisión Especificación de Requerimientos Equipo Funcional |  | 5d | 2005-05-26 | 2005-06-01 | 27 | 70d | 0d |  | Corp. Union | 40h |
| 29 | 1.2.5 | Aprobación del Informe Especificación de Requerimientos | milestone | 0d | 2005-06-03 | 2005-06-03 |  | 69d |  | start no earlier than 2005-06-03 | Corp. Union |  |

| ID | WBS | Task | Type | Duration | Start | Finish | Predecessors | Total slack | Free slack | Constraint | Resources | Work |
| --- | --- | --- | --- | --- | --- | --- | --- | --- | --- | --- | --- | --- |
| 30 | 1.2.6 | **Sistemas Operacionales Involucrados** |  | 35d | 2005-04-08 | 2005-05-27 |  | 73d |  |  |  | 144h |
| 31 | 1.2.6.1 | Presentación CLS y Resort Link |  | 1d | 2005-04-12 | 2005-04-12 |  | 105d |  | start no earlier than 2005-04-12 | Corp. Union; Listbeth; Olga | 24h |
| 32 | 1.2.6.2 | Presentación Consulta Integral Versión actual |  | 1d | 2005-04-08 | 2005-04-08 |  | 107d |  | start no earlier than 2005-04-08 | Corp. Union; Listbeth; Olga | 24h |
| 33 | 1.2.6.3 | Presentación Consulta Integral Nueva versión |  | 1d | 2005-04-15 | 2005-04-15 |  | 102d |  | start no earlier than 2005-04-15 | Corp. Union; Listbeth; Olga | 24h |
| 34 | 1.2.6.4 | Presentación Sistema CLS y Tarifario |  | 1d | 2005-05-05 | 2005-05-05 |  | 89d |  | start no earlier than 2005-05-05 | Corp. Union; Listbeth; Gaby | 24h |
| 35 | 1.2.6.5 | Recepción Inf. Plataforma Técnica y Diccionario de Datos |  | 3d | 2005-04-18 | 2005-04-21 |  | 99d |  | start no earlier than 2005-04-18 | Corp. Union; Listbeth | 48h |
| 36 | 1.2.6.6 | Análisis Estructura de Datos |  | 5d | 2005-05-23 | 2005-05-27 |  | 73d |  | start no earlier than 2005-05-23 |  |  |
| 37 | 1.3 | Informe Especificación de Requerimientos Aprobado | milestone | 0d | 2005-06-01 | 2005-06-01 | 28 | 70d |  | start no earlier than 2005-05-23 |  |  |
| 38 | 1.4 | Matriz de Requerimientos Revisada y Aprobada | milestone | 0d | 2005-06-01 | 2005-06-01 | 28 | 70d |  | start no earlier than 2005-05-23 |  |  |
| 39 | 1.5 | **Diseño** |  | 8d | 2005-05-26 | 2005-06-06 |  | 17d |  |  |  | 288h |
| 40 | 1.5.1 | Elaboración Diseño Lógico y Físico de la aplicación |  | 5d | 2005-05-26 | 2005-06-01 | 27 | 17d | 0d |  | Agustín; Loredana; Gaby; Olga [50%]; Listbeth | 180h |
| 41 | 1.5.2 | Análisis de tablas y aplicaciones administrativas |  | 3d | 2005-06-02 | 2005-06-06 | 40 | 17d | 0d |  | Agustín; Loredana; Gaby; Olga [50%]; Listbeth | 108h |
| 42 | 1.6 | Diseño de la Aplicación Completado | milestone | 0d | 2005-06-01 | 2005-06-01 | 40 | 70d |  |  |  |  |
| 43 | 1.7 | Modelo E-R Completado | milestone | 0d | 2005-06-06 | 2005-06-06 | 41 | 67d |  |  |  |  |
| 44 | 1.8 | **Plan de Pruebas** |  | 11d | 2005-06-07 | 2005-06-21 |  | 56d |  |  |  | 184h |
| 45 | 1.8.1 | Elaboración Plan de Pruebas |  | 5d | 2005-06-07 | 2005-06-13 | 41 | 56d | 0d |  | Olga [50%]; Listbeth [50%] | 40h |
| 46 | 1.8.2 | Revisión Plan de Pruebas con Equipo de Trabajo |  | 3d | 2005-06-14 | 2005-06-16 | 45 | 56d | 0d |  | Listbeth; Olga; Loredana; Gaby; Agustín | 120h |
| 47 | 1.8.3 | Ajustes recomendados al Plan de Pruebas |  | 3d | 2005-06-17 | 2005-06-21 | 46 | 56d | 0d |  | Olga | 24h |
| 48 | 1.9 | Plan de Pruebas elaborado y revisado | milestone | 0d | 2005-06-21 | 2005-06-21 | 47 | 56d |  |  |  |  |
| 49 | 1.10 | **Configuración técnica (N2C y WIB)** |  | 64d | 2005-05-12 | 2005-08-11 |  | 21d |  |  |  | 1508.29h |
| 50 | 1.10.1 | Crear aplicación, tablas y atributos |  | 5d | 2005-06-07 | 2005-06-13 | 41 | 17d | 0d | start no earlier than 2005-05-16 | Loredana; Gaby; Agustín | 120h |
| 51 | 1.10.2 | Configuración Aplic. (Adm. de Sev., FAQ, galería de fotos, etc.) |  | 35d | 2005-06-14 | 2005-08-03 | 50 | 17d | 0d |  | Loredana; Gaby; Agustín | 840h |
| 52 | 1.10.3 | Configuración Integración con Sist. Operac (CLS, Tarifario, TC) |  | 30d | 2005-06-30 | 2005-08-11 |  | 0d |  | start no earlier than 2005-06-30 | Gaby | 240h |
| 53 | 1.10.4 | Configuración WIB |  | 45d | 2005-05-12 | 2005-07-15 |  | 40d |  | start no earlier than 2005-05-12 | Félix [25%]; Agustín [50%]; Olga [25%] | 244.29h |
| 54 | 1.10.5 | Presentación Prototipo # 1 |  | 2d | 2005-06-30 | 2005-07-01 |  | 49d |  | start no earlier than 2005-06-30 | Loredana; Listbeth | 32h |
| 55 | 1.10.6 | Presentación Prototipo # 2 |  | 2d | 2005-07-28 | 2005-07-29 |  | 30d |  | start no earlier than 2005-07-28 | Gaby; Listbeth | 32h |
| 56 | 1.11 | Solución Configurada | milestone | 0d | 2005-08-03 | 2005-08-03 | 51 | 17d | 0d |  |  |  |

| ID | WBS | Task | Type | Duration | Start | Finish | Predecessors | Total slack | Free slack | Constraint | Resources | Work |
| --- | --- | --- | --- | --- | --- | --- | --- | --- | --- | --- | --- | --- |
| 57 | 1.12 | **Pruebas de Certificación** |  | 10d | 2005-08-12 | 2005-08-25 |  | 0d |  |  |  | 140h |
| 58 | 1.12.1 | Preparación de datos para las pruebas |  | 5d | 2005-08-12 | 2005-08-18 | 52 | 0d |  | start no earlier than 2005-06-20 | Corp. Union | 40h |
| 59 | 1.12.2 | Realización de Pruebas de Funcionalidad |  | 5d | 2005-08-19 | 2005-08-25 | 58 | 0d |  | start no earlier than 2005-07-12 | Corp. Union; Listbeth; Olga [50%] | 100h |
| 60 | 1.13 | Pruebas de Certificación aprobada | milestone | 0d | 2005-08-25 | 2005-08-25 | 59 | 0d |  |  |  |  |
| 61 | 1.14 | **Preparación para el aranque** |  | 24d | 2005-07-25 | 2005-08-25 |  | 11d |  |  |  | 216h |
| 62 | 1.14.1 | Configuración Infraestructura Técnica |  | 2d | 2005-08-12 | 2005-08-15 | 52, 60 | 11d | 0d |  | Corp. Union; Gaby | 32h |
| 63 | 1.14.2 | Revisión / prperación Información y material a publicar |  | 15d | 2005-07-25 | 2005-08-12 | 60 | 20d |  | start no earlier than 2005-07-25 | Corp. Union | 120h |
| 64 | 1.14.3 | Ajustes a la configuración y Web Services |  | 8d | 2005-08-16 | 2005-08-25 | 62 | 11d |  | start no earlier than 2005-07-19 | Gaby | 64h |
| 65 | 1.15 | **Documentación** |  | 10d | 2005-08-04 | 2005-08-17 |  | 17d |  |  |  | 120h |
| 66 | 1.15.1 | Guía del Usuario - Administrador de la solución |  | 10d | 2005-08-04 | 2005-08-17 | 56 | 17d |  |  | Loredana; Listbeth [50%] | 120h |
| 67 | 1.16 | **Adiestramiento** |  | 21d | 2005-08-04 | 2005-09-01 |  | 6d |  |  |  | 260h |
| 68 | 1.16.1 | Preparación Material |  | 10d | 2005-08-04 | 2005-08-17 | 56 | 17d |  | start no earlier than 2005-07-18 | Loredana; Olga [50%] | 120h |
| 69 | 1.16.2 | Taller de Adiestramiento - Administrador WIB y Back-Office |  | 5d | 2005-08-26 | 2005-09-01 | 60 | 0d |  |  | Listbeth; Gaby; Olga [50%]; Loredana | 140h |
| 70 | 1.17 | Puesta en Producción |  | 2d | 2005-09-02 | 2005-09-05 | 69 | 0d |  |  | Corp. Union; Gaby; Listbeth | 48h |
| 71 | 1.18 | Manejo del Cambio |  | 30d | 2005-08-01 | 2005-09-09 |  | 0d |  | finish no earlier than 2005-09-09 | Corp. Union [25%]; Listbeth [25%]; Olga [50%] | 240h |
| 72 | 1.19 | **Gerencia de Proyecto** |  | 25d | 2005-04-20 | 2005-05-24 |  | 76d |  |  |  | 200h |
| 73 | 1.19.1 | Planificación |  | 25d | 2005-04-20 | 2005-05-24 |  | 76d |  | start no earlier than 2005-04-20 | Listbeth | 200h |
| 74 | 1.20 | **Cierre** |  | 4d | 2005-09-06 | 2005-09-09 |  | 0d |  |  |  | 40h |
| 75 | 1.20.1 | Preparación Presentación Cierre de Proyecto |  | 3d | 2005-09-06 | 2005-09-08 | 70 | 0d |  |  | Listbeth | 24h |
| 76 | 1.20.2 | Reunión Cierre de Proyecto |  | 1d | 2005-09-09 | 2005-09-09 | 75 | 0d |  |  | Corp. Union; Listbeth | 16h |
