# TravelActive

Schedule from MS Project, 2005-11-07 to 2005-11-22, costs in €.
PERSONAL

## Calendars

- Standard: Mon-Fri 08:00-12:00, 13:00-17:00; Sat-Sun off.

## Resources

| Resource | Rate |
| --- | --- |
| Travel Actief |  |
| Foto XS |  |
| GWT1 | 30 |
| Tierra Network |  |
| GWT2 | 30 |
| PM | 50 |

## Schedule

| ID | WBS | Task | Duration | Start | Finish | Predecessors | Total slack | Free slack | Constraint | Resources | Work | Cost | Text20 | Text21 |
| --- | --- | --- | --- | --- | --- | --- | --- | --- | --- | --- | --- | --- | --- | --- |
| 1 | 1 | **Travel Actief Action** | 11.42d | 2005-11-07 08:00 | 2005-11-22 11:20 |  | 0d |  |  |  | 198.8h | 4,200 | 0. Total Project | 0. Black |
| 2 | 1.1 | Project Management | 11d | 2005-11-07 08:00 | 2005-11-21 17:00 |  | 0.42d |  |  | PM [10%] | 8.8h | 440 |  |  |
| 3 | 1.2 | **Integration with TA System: Single Sign-On** | 2.92d | 2005-11-07 08:00 | 2005-11-09 16:20 |  | 0d |  |  |  | 48h | 700 | 1. Urgent Corrections | 0. Black |
| 4 | 1.2.1 | Design authentication method to verify valid sign on requests from the TA system that don't imply the trannsmission of the user's password over the Internet. | 0.67d | 2005-11-07 08:00 | 2005-11-07 14:20 |  | 0d |  |  | Tierra Network; Travel Actief; GWT1 | 16h | 160 |  |  |
| 5 | 1.2.2 | Implement mechanism in FotoXS system | 1.5d | 2005-11-07 14:20 | 2005-11-09 09:20 | 4 | 0d |  |  | GWT1 | 12h | 360 |  |  |
| 6 | 1.2.3 | Implement mechanism in TA system | 1d | 2005-11-07 14:20 | 2005-11-08 14:20 | 4 | 0.5d |  |  | Travel Actief | 8h |  |  |  |
| 7 | 1.2.4 | Integrate and test | 0.75d | 2005-11-09 09:20 | 2005-11-09 16:20 | 5, 6 | 0d |  |  | Tierra Network; GWT1 | 12h | 180 |  |  |
| 8 | 1.3 | **Integration with TA System: automatic data synchronyzation and accounts creation** | 2.75d | 2005-11-09 16:20 | 2005-11-14 14:20 | 7 | 0d |  |  |  | 40h | 660 | 1. Urgent Corrections | 0. Black |
| 9 | 1.3.1 | Design export format and transfer method. | 0.5d | 2005-11-09 16:20 | 2005-11-10 11:20 |  | 0d |  |  | Tierra Network; GWT1 | 8h | 120 |  |  |
| 10 | 1.3.2 | Implement automatic process (daemon) to process the exports. | 1d | 2005-11-10 11:20 | 2005-11-11 11:20 | 9 | 0d |  |  | GWT1 | 8h | 240 |  |  |
| 11 | 1.3.3 | Develop automatic process to send the exports from the TA system | 1d | 2005-11-10 11:20 | 2005-11-11 11:20 | 9 | 0d |  |  | Travel Actief | 8h |  |  |  |
| 12 | 1.3.4 | Process for creation of special accounts with special projects | 0.5d | 2005-11-11 11:20 | 2005-11-11 16:20 | 11, 10 | 0d |  |  | GWT1 | 4h | 120 |  |  |
| 13 | 1.3.5 | Test export processing. | 0.25d | 2005-11-11 16:20 | 2005-11-14 09:20 | 12 | 0d |  |  | Tierra Network; GWT1 | 4h | 60 |  |  |
| 14 | 1.3.6 | Test and adjust special accounts behavior (discounts, pre-loaded projects, etc…) | 0.5d | 2005-11-14 09:20 | 2005-11-14 14:20 | 13 | 0d |  |  | Tierra Network; GWT1 | 8h | 120 |  |  |
| 15 | 1.4 | **Public album viewing** | 4.5d | 2005-11-14 14:20 | 2005-11-21 09:20 | 14 | 1.25d |  |  |  | 38h | 900 | 1. Urgent Corrections | 0. Black |
| 16 | 1.4.1 | Possibility of marking albums as "public" | 0.25d | 2005-11-14 14:20 | 2005-11-14 16:20 |  | 2d | 0.75d |  | GWT1 | 2h | 60 |  |  |
| 17 | 1.4.2 | Design Look & Feel and navigation of pages for "Album Viewing" (slideshows, actiuon buttons, page jumping tools, etc…) | 1d | 2005-11-14 14:20 | 2005-11-15 14:20 |  | 1.25d | 0d |  | Foto XS | 8h |  |  |  |
| 18 | 1.4.3 | Develop pages for album viewing restricted to owner from Mijn FotoXS or general public if the project is marked as "public". | 2.5d | 2005-11-15 14:20 | 2005-11-18 09:20 | 17, 16 | 1.25d | 0d |  | GWT1 | 20h | 600 |  |  |
| 19 | 1.4.4 | Implement authentication mechanism to restrict access of general public to the link in the user's space in the TA system. | 1d | 2005-11-18 09:20 | 2005-11-21 09:20 | 18 | 1.25d |  |  | GWT1 | 8h | 240 |  |  |
| 20 | 1.5 | **Special projects in Mijn FotoXS** | 2.25d | 2005-11-14 14:20 | 2005-11-16 16:20 | 14 | 0d |  |  |  | 18h | 420 | 1. Urgent Corrections | 0. Black |
| 21 | 1.5.1 | Design look & feel modifications and special icons needed to mark special TA public albums in the pages of Mijn FotoXS | 0.5d | 2005-11-14 14:20 | 2005-11-15 09:20 |  | 0d |  |  | Foto XS | 4h |  |  |  |
| 22 | 1.5.2 | Include new icons and designs in the pages that display projects (Mijn FotoXS, Delen and Album Maker) [DEVELOPMENT ENVIRONMENT] | 1.5d | 2005-11-15 09:20 | 2005-11-16 14:20 | 21 | 0d |  |  | GWT2 | 12h | 360 |  |  |
| 23 | 1.5.3 | Test and upload to Holland [PRODUCTION ENVIRONMENT] | 0.25d | 2005-11-16 14:20 | 2005-11-16 16:20 | 22 | 0d |  | start no earlier than 2005-11-08 08:00 | GWT2 | 2h | 60 |  |  |
| 24 | 1.6 | **Free projects in Mijn FotoXS and Shopping Cart (Winkeltaas)** | 3.5d | 2005-11-16 16:20 | 2005-11-22 11:20 | 23 | 0d |  |  |  | 46h | 1,080 | 1. Urgent Corrections | 0. Black |
| 25 | 1.6.1 | Design look & feel modifications and special icons needed to mark special free albums in the pages of Mijn FotoXS, and the shopping cart | 0.5d | 2005-11-16 16:20 | 2005-11-17 11:20 |  | 0d |  |  | Foto XS | 4h |  |  |  |
| 26 | 1.6.2 | Possibility of marking projects as free or pre-paid (just for one purchase) | 0.25d | 2005-11-17 11:20 | 2005-11-17 14:20 | 25 | 0d |  |  | GWT2 | 2h | 60 |  |  |
| 27 | 1.6.3 | Include new icons and designs in the pages that display projects (Mijn FotoXS,and Winkeltaas) | 1.5d | 2005-11-17 14:20 | 2005-11-21 09:20 | 26 | 0.75d |  |  | GWT2 | 12h | 360 |  |  |
| 28 | 1.6.4 | Modify price calculation process in Winkeltaas to incorporate free projects (only one copy) and marked them as regular once the promotion has been used once [DEVELOPMENT ENVIRONMENT] | 1.5d | 2005-11-17 14:20 | 2005-11-21 09:20 | 26 | 0d |  |  | GWT2 | 12h | 360 |  |  |
| 29 | 1.6.5 | Test price calculation when first purchasing the special album and once the promotion has been used. Make adjustments needed | 0.75d | 2005-11-21 09:20 | 2005-11-21 16:20 | 28 | 0d |  |  | Tierra Network; GWT2 | 12h | 180 |  |  |
| 30 | 1.6.6 | Test all and upload to Holland [PRODUCTION ENVIRONMENT] | 0.5d | 2005-11-21 16:20 | 2005-11-22 11:20 | 27, 29 | 0d |  |  | GWT2 | 4h | 120 |  |  |

Notes:
- 1: Users that are registered in the Travel Actief site should automaticly have a FotoXS account with the same login and password. This account has to have the usual privileges for all partner accounts plus a pre-paid Deluxe Album of 60 pages. This album has to be public, meaning that anybody that accesses the users special space in Travel Actief should be able to see that album (in viewing quality) by just clicking a link. The public accessing this album can only see the photos and text, but cannot edit or buy the album à they wont be inside the FotoXS environment (shop, etc….). / The travel actief users should have a link in their TA space that takes them DIRECTLY to Mijn FotoXS (without a second log in).
- 3: Possibility of accessing the site without submitting a password, guaranteeing that it can only be done when requested by the TA system once the user has logged in there. (Develop a secure mechanism of communication and integration between both modules)
- 8: Automated mechanism that processes daily exports from the TA System and creates special accounts that are already active and have a special project created with the following characteristics: / ·Album DeLuxe / ·60 pages / ·Available to the general public for viewing. / ·Possibly free (pre-paid)
- 15: Special page for viewing albums content (like shared Yahoo or Msn albums, slideshows, etc…) that displays the pages of the project -in the desired quality and size for the public- allowing them to navigate through them. This page has to be designed (visually) but will not have functionality from the FotoXS site, is just going to be a Viewer. It should validate that the album that the public is trying to access is in fact a public album (the mechanism to mark them as so needs to be incorporated) and if desired it should also guarantee that the access was made from the users space in TA.
- 20: If desired, modifying pages in the site so they can display special projects (such as the free album in this promotion) differently and possibly restrict the actions to take on it (Changing the name, deleting, etc….)
- 24: Possibility of marking projects as Free so they can be treated specially by the shopping cart mechanism and can be bought for 0 € (only one copy, and only once). If desired, modifying shopping cart and purchase pages so they reflect this special promotion as it is being used (Icons, markers, special texts, new lines in factuur, etc….).
