# ttpropuestas

Schedule from MS Project, 2005-11-23 to 2006-02-08, A marks actual dates.
GWT

## Calendars

- Estándar: Mon-Fri 09:00-13:00, 15:00-19:00; Sat-Sun off.

## Resources

| Resource |
| --- |
| V Riera |
| H Rosas V Riera |
| O Lorenzo |
| O Lorenzo V Riera |

## Schedule

| ID | WBS | Task | Duration | Start | Finish | Predecessors | Complete | Remaining | Baseline start | Baseline finish | Baseline duration | Total slack | Constraint | Resources | Work | Actual work |
| --- | --- | --- | --- | --- | --- | --- | --- | --- | --- | --- | --- | --- | --- | --- | --- | --- |
| 1 | 1 | **Manejo de Propuestas** | 56d? | 2005-11-23 A | 2006-02-08 |  | 34% | 37.06d? | 2005-11-23 | 2006-02-08 | 56d? | 0d |  |  | 256h | 84h |
| 3 | 1.1 | Inicio | 1d? | 2005-11-23 A | 2005-11-23 A |  | 100% |  | 2005-11-23 | 2005-11-23 | 1d? |  | start no earlier than 2005-11-23 |  |  |  |
| 4 | 1.2 | Definición de los elementos que conforma la propuesta | 5d | 2005-11-23 A | 2005-11-29 A |  | 100% |  | 2005-11-23 | 2005-11-29 | 5d |  | start no earlier than 2005-11-23 | V Riera | 40h | 40h |
| 5 | 1.3 | Establecimiento del modelo de propuestas | 5d | 2005-11-30 A | 2005-12-06 A | 4 | 100% |  | 2005-11-30 | 2005-12-06 | 5d |  |  | V Riera | 40h | 40h |
| 6 | 1.4 | Establecimiento de procesos de la elaboración de la propuesta y los procedimientos | 5d | 2005-12-07 A | 2005-12-13 | 5 | 10% | 4.5d | 2005-12-07 | 2005-12-13 | 5d | 41d |  | V Riera | 40h | 4h |
| 7 | 1.5 | Incorporación a 701 | 10d | 2006-01-16 | 2006-01-27 |  |  |  | 2006-01-16 | 2006-01-27 | 10d | 0d | start no earlier than 2006-01-16 | H Rosas V Riera | 80h |  |
| 8 | 1.6 | Prueba de Sistema | 7d | 2006-01-30 | 2006-02-07 | 7 |  |  | 2006-01-30 | 2006-02-07 | 7d | 0d |  | O Lorenzo V Riera | 56h |  |
| 9 | 1.7 | Cierre | 1d | 2006-02-08 | 2006-02-08 | 8 |  |  | 2006-02-08 | 2006-02-08 | 1d | 0d |  |  |  |  |
