# ttmercadeo

Schedule from MS Project, 2006-01-12 to 2006-02-13, A marks actual dates.
GWT

## Calendars

- Estándar: Mon-Fri 09:00-13:00, 15:00-19:00; Sat-Sun off.

## Resources

| Resource |
| --- |
| V Riera |
| H Rosas V Riera |
| O Lorenzo |
| O Lorenzo V Riera |

## Schedule

| ID | WBS | Task | Duration | Start | Finish | Predecessors | Complete | Baseline start | Baseline finish | Baseline duration | Constraint | Resources | Work | Actual work |
| --- | --- | --- | --- | --- | --- | --- | --- | --- | --- | --- | --- | --- | --- | --- |
| 1 | 1 | **Mercadeo** | 23d? | 2006-01-12 A | 2006-02-13 A |  | 100% | 2005-11-23 | 2006-02-08 | 56d? |  |  | 56h | 56h |
| 3 | 1.1 | Inicio | 1d? | 2006-01-20 A | 2006-01-20 A |  | 100% | 2005-11-23 | 2005-11-23 | 1d? | start no earlier than 2005-11-23 |  |  |  |
| 4 | 1.2 | Definición de los elementos que conforman el Plan de Mercadeo | 5d | 2006-01-24 A | 2006-01-30 A |  | 100% | 2005-11-23 | 2005-11-29 | 5d | start no earlier than 2005-11-23 | V Riera | 40h | 40h |
| 5 | 1.3 | Establecimiento del modelo de Plan de Mercadeo | 1d | 2006-02-03 A | 2006-02-03 A | 4 | 100% | 2005-11-30 | 2005-12-06 | 5d |  | V Riera | 8h | 8h |
| 6 | 1.4 | **Establecimiento de procesos de la elaboración del plan de mercadeo** | 13d? | 2006-01-12 A | 2006-01-30 A |  | 100% | 2005-12-14 | 2006-01-12 | 0d? |  |  |  |  |
| 7 | 1.4.1 | Definición de Procesos | 1d? | 2006-01-24 A | 2006-01-24 A |  | 100% | 2005-12-14 | 2005-12-14 | 0d? | finish no earlier than 2005-12-14 |  |  |  |
| 8 | 1.4.2 | Definición de Procedimientos | 1d? | 2006-01-24 A | 2006-01-24 A |  | 100% | 2005-12-14 | 2005-12-14 | 0d? | finish no earlier than 2005-12-14 |  |  |  |
| 9 | 1.4.3 | Establecer componentes a proponer en el sistema | 13d? | 2006-01-12 A | 2006-01-30 A |  | 100% | 2006-01-12 | 2006-01-18 | 0d? | finish no earlier than 2006-01-30 |  |  |  |
| 10 | 1.5 | **Incorporación a 701?** | 1d? | 2006-02-13 A | 2006-02-13 A |  | 100% | 2006-01-20 | 2006-01-27 | 10d |  | H Rosas V Riera | 8h | 8h |
| 11 | 1.5.1 | Establecer componentes definitivos del sistema? | 1d? | 2006-02-13 A | 2006-02-13 A |  | 100% | 2006-01-20 | 2006-01-27 | 0d? | start no earlier than 2006-02-13 |  |  |  |
| 12 | 1.5.2 | Incorporar los componentes en la 701? | 1d? | 2006-02-13 A | 2006-02-13 A |  | 100% |  |  |  | start no earlier than 2006-03-20 |  |  |  |
| 13 | 1.5.3 | Probar sistema | 1d? | 2006-02-13 A | 2006-02-13 A |  | 100% |  |  |  | finish no earlier than 2006-03-01 |  |  |  |
| 14 | 1.5.4 | Aprobar sistema | 1d? | 2006-02-13 A | 2006-02-13 A | 13 | 100% |  |  |  |  |  |  |  |
| 15 | 1.6 | Cierre | 1d | 2006-02-13 A | 2006-02-13 A |  | 100% | 2006-02-08 | 2006-02-08 | 1d | start no earlier than 2006-03-03 |  |  |  |
