# Proyecto CRM - Corporacion Union

Schedule from MS Project, 2007-09-04 to 2007-09-26.

## Calendars

- Estándar: Mon-Fri 08:00-12:00, 13:00-17:00; Sat-Sun off.

## Resources

| Resource |
| --- |
| MH |
| GP |
| Oasis |
| Oasist |
| Operaciones |

## Schedule

| ID | WBS | Task | Type | Duration | Start | Finish | Predecessors | Total slack | Free slack | Constraint | Resources | Work |
| --- | --- | --- | --- | --- | --- | --- | --- | --- | --- | --- | --- | --- |
| 1 | 1 | **Proyecto Gestor de Documentos** |  | 17d | 2007-09-04 | 2007-09-26 |  | 0d |  |  |  | 91h |
| 2 | 1.1 | Reunión de Arranque |  | 0.5d | 2007-09-04 | 2007-09-04 |  | 16.25d | 0d | start no earlier than 2007-09-04 | MH [50%]; GP [50%] | 4h |
| 3 | 1.2 | Análsis y preparación material para definición requerimientos |  | 0.25d | 2007-09-04 | 2007-09-04 | 2 | 16.25d |  |  | GP | 2h |
| 4 | 1.3 | **Especificación de Requerimientos** |  | 5.17d | 2007-09-05 | 2007-09-12 |  | 0d |  |  |  | 10h |
| 5 | 1.3.1 | Elaboración del Informe Especificación de Req. |  | 1d | 2007-09-05 | 2007-09-05 |  | 0d |  | start no earlier than 2007-09-05 | MH [50%] | 4h |
| 6 | 1.3.2 | Entrega al Equipo de Proyecto para su revisión | milestone | 0d | 2007-09-05 | 2007-09-05 | 5 | 0d |  |  | GP |  |
| 7 | 1.3.3 | Revisión por parte del Equipo de Proyecto | milestone | 0d | 2007-09-05 | 2007-09-05 | 6 | 0d |  |  | Oasis |  |
| 8 | 1.3.4 | Recepción de ajustes recomendados al Informe | milestone | 0d | 2007-09-05 | 2007-09-05 | 7 | 0d |  |  | GP |  |
| 9 | 1.3.5 | Ajustes al Informe Especificación de Requerimientos |  | 2.5d | 2007-09-06 | 2007-09-10 | 8 | 0d |  |  | MH [50%]; GP [10%] | 4h |
| 10 | 1.3.6 | Entrega de Especificación de Req. para aprobación | milestone | 0d | 2007-09-10 | 2007-09-10 | 9 | 0d |  |  | GP |  |
| 11 | 1.3.7 | Aprobación del Informe Especificación de Requerimientos |  | 1.67d | 2007-09-10 | 2007-09-12 | 10 | 0d |  |  | GP [5%]; MH [25%]; Oasis [50%] | 2h |
| 12 | 1.3.8 | Informe Especificación de Requerimientos Aprobado | milestone | 0d | 2007-09-12 | 2007-09-12 | 11 | 0d |  |  |  |  |
| 13 | 1.4 | **Preparación de la información base para implantación** |  | 2.5d | 2007-09-12 | 2007-09-14 |  | 1.33d | 0d |  |  | 4h |
| 14 | 1.4.1 | Usuarios y perfiles |  | 2.5d | 2007-09-12 | 2007-09-14 | 4 | 1.33d | 0d |  | Oasis [25%]; MH [50%]; GP [5%] | 4h |
| 15 | 1.4.2 | Entrega de información para implantación a GWT | milestone | 0d | 2007-09-14 | 2007-09-14 | 14 | 1.33d |  |  |  |  |
| 16 | 1.5 | **Configuración y Desarrollo** |  | 7d | 2007-09-14 | 2007-09-25 |  | 1.33d | 0d |  |  | 28h |
| 17 | 1.5.1 | **Configuración Nuevas Aplicaciones** |  | 7d | 2007-09-14 | 2007-09-25 |  | 1.33d |  |  |  | 28h |
| 18 | 1.5.1.1 | Menú de Ingreso a aplicaciones |  | 1d | 2007-09-14 | 2007-09-17 | 13 | 1.33d | 0d |  | MH [50%] | 4h |
| 19 | 1.5.1.2 | Gestión de Documentos |  | 5d | 2007-09-17 | 2007-09-24 | 18 | 1.33d | 0d |  | MH [50%] | 20h |
| 20 | 1.5.1.3 | Look&feel aplicación |  | 1d | 2007-09-24 | 2007-09-25 | 19 | 1.33d |  |  | MH [50%] | 4h |
| 21 | 1.6 | Nuevas funcionalidades en la Intranet incorporadas | milestone | 0d | 2007-09-25 | 2007-09-25 | 16 | 1.33d |  |  |  |  |
| 22 | 1.7 | **Plan de Pruebas** |  | 2.25d | 2007-09-12 | 2007-09-14 |  | 0d |  |  |  | 3h |
| 23 | 1.7.1 | Elaboración Plan de Pruebas |  | 0.5d | 2007-09-12 | 2007-09-12 | 12 | 0d |  |  | GP [25%] | 1h |
| 24 | 1.7.2 | Revisión Plan de Pruebas con Equipo de Trabajo |  | 1.25d | 2007-09-12 | 2007-09-13 | 23 | 0d |  |  | Oasis [5%]; GP [5%] | 1h |
| 25 | 1.7.3 | Ajustes al Plan de Pruebas |  | 0.5d | 2007-09-13 | 2007-09-14 | 24 | 0d |  |  | GP [25%] | 1h |
| 26 | 1.8 | Plan de Pruebas elaborado y revisado | milestone | 0d | 2007-09-14 | 2007-09-14 | 25 | 8.58d |  |  |  |  |

| ID | WBS | Task | Type | Duration | Start | Finish | Predecessors | Total slack | Free slack | Resources | Work |
| --- | --- | --- | --- | --- | --- | --- | --- | --- | --- | --- | --- |
| 27 | 1.9 | **Pruebas de Certificación** |  | 2d | 2007-09-14 | 2007-09-18 |  | 0d |  |  | 12h |
| 28 | 1.9.1 | Preparación para las pruebas en ambiente de desarrollo |  | 0.5d | 2007-09-14 | 2007-09-14 | 22 | 0d |  | MH [50%] | 2h |
| 29 | 1.9.2 | Realización de Pruebas de Funcionalidad |  | 1d | 2007-09-14 | 2007-09-17 | 28 | 0d |  | GP [5%]; MH [50%]; Oasis | 8h |
| 30 | 1.9.3 | Realización de Ajustes recomendados |  | 0.5d | 2007-09-17 | 2007-09-18 | 29 | 0d |  | MH [50%] | 2h |
| 31 | 1.10 | Pruebas Certificadas | milestone | 0d | 2007-09-18 | 2007-09-18 | 30 | 0d |  |  |  |
| 32 | 1.11 | **Documentación** |  | 1d | 2007-09-18 | 2007-09-19 |  | 5.08d | 0d |  | 4h |
| 33 | 1.11.1 | Elaboración de Guia de Usuario |  | 1d | 2007-09-18 | 2007-09-19 | 31 | 5.08d |  | MH [50%] | 4h |
| 34 | 1.12 | **Adiestramiento** |  | 0.5d | 2007-09-19 | 2007-09-19 |  | 5.08d |  |  | 4h |
| 35 | 1.12.1 | Aplicaciones |  | 0.5d | 2007-09-19 | 2007-09-19 | 32 | 5.08d |  | MH | 4h |
| 36 | 1.13 | **Puesta en Producción** |  | 5.33d | 2007-09-18 | 2007-09-25 |  | 0d |  |  | 8h |
| 37 | 1.13.1 | Migración de aplicaciones |  | 2d | 2007-09-18 | 2007-09-20 | 31 | 0d |  | Operaciones [25%] | 4h |
| 38 | 1.13.2 | Pruebas integrales |  | 3.33d | 2007-09-20 | 2007-09-25 | 37 | 0d |  | Oasis [50%]; GP [5%]; MH [50%] | 4h |
| 39 | 1.14 | **Gerencia de Proyecto** |  | 10d | 2007-09-12 | 2007-09-26 |  | 0.83d |  |  | 8h |
| 40 | 1.14.1 | Planificación |  | 5d | 2007-09-12 | 2007-09-19 | 4 | 0.83d | 0d | GP [10%] | 4h |
| 41 | 1.14.2 | Control y Seguimiento |  | 5d | 2007-09-19 | 2007-09-26 | 40 | 0.83d |  | GP [10%] | 4h |
| 42 | 1.15 | **Cierre** |  | 1.25d | 2007-09-25 | 2007-09-26 |  | 0d |  |  | 4h |
| 43 | 1.15.1 | Preparación Presentación Cierre de Proyecto |  | 1d | 2007-09-25 | 2007-09-26 | 36 | 0d |  | GP [25%] | 2h |
| 44 | 1.15.2 | Reunión Cierre de Proyecto |  | 0.25d | 2007-09-26 | 2007-09-26 | 43 | 0d |  | GP | 2h |
