# Seventec Propuesta

Schedule from MS Project, 2007-11-09 to 2008-01-16, costs in Bs.
GlobalWebTek

## Calendars

- Standard: Mon-Fri 08:00-12:00, 13:00-17:00; Sat-Sun off. Exceptions (off unless hours are given): 2007-12-24 to 2007-12-25, 2007-12-31 to 2008-01-01.

## Resources

| Resource | Rate |
| --- | --- |
| MR | 15000 |
| EC | 6250 |
| DS | 6250 |
| LR |  |
| AL | 15000 |
| GP |  |
| OP |  |

## Schedule

| ID | WBS | Task | Duration | Start | Finish | Predecessors | Total slack | Free slack | Constraint | Resources | Work | Cost |
| --- | --- | --- | --- | --- | --- | --- | --- | --- | --- | --- | --- | --- |
| 1 | 1 | **Control de Servicios de Infraestructura** | 44.93d? | 2007-11-09 | 2008-01-16 |  | 0d |  |  |  | 226h | 899,305.56 |
| 2 | 1.1 | **Inicio** | 0.12d | 2007-11-09 | 2007-11-09 |  | 10.57d |  |  |  | 1h |  |
| 3 | 1.1.1 | Reunión de Kickoff | 1h | 2007-11-09 | 2007-11-09 |  | 10.57d | 0d | start no earlier than 2007-11-09 | GP | 1h |  |
| 4 | 1.2 | **FASE I** | 44.81d? | 2007-11-09 | 2008-01-16 |  | 0d |  |  |  | 201h | 899,305.56 |
| 5 | 1.2.1 | **Levantamiento de Información** | 0.5d | 2007-11-12 | 2007-11-12 |  | 0d |  |  |  | 4h |  |
| 6 | 1.2.1.1 | Sesión de Trabajo única | 4h | 2007-11-12 | 2007-11-12 |  | 0d |  | start no earlier than 2007-11-12 | GP | 4h |  |
| 7 | 1.2.2 | **Requerimientos, Análisis y Diseño** | 12.07d | 2007-11-09 | 2007-11-27 |  | 0d |  |  |  | 38h | 55,555.56 |
| 8 | 1.2.2.1 | Creación de ambiente N2C de Desarrollo | 4h | 2007-11-09 | 2007-11-09 | 3 | 10.57d |  | start no earlier than 2006-10-31 | OP | 4h |  |
| 9 | 1.2.2.2 | Documento de Especificación de Requerimientos | 4d | 2007-11-12 | 2007-11-16 | 5 | 0d |  | finish no earlier than 2006-11-03 | GP [50%] | 16h |  |
| 10 | 1.2.2.3 | Revisión por parte del Cliente | 1d | 2007-11-16 | 2007-11-19 | 9 | 0d |  |  |  |  |  |
| 11 | 1.2.2.4 | Ajustes Documento de Especificaciones | 10h | 2007-11-19 | 2007-11-20 | 10 | 0d |  | start no earlier than 2006-11-10 | GP [20%] | 2h |  |
| 12 | 1.2.2.5 | Análisis y Diseño | 4.44d | 2007-11-20 | 2007-11-27 | 11 | 0d |  |  | GP [20%]; DS [25%] | 16h | 55,555.56 |
| 13 | 1.2.3 | **Desarrollo** | 31.41d? | 2007-11-27 | 2008-01-15 |  | 0d |  |  |  | 147h | 843,750 |
| 14 | 1.2.3.1 | Modelo de Datos | 1d? | 2007-11-27 | 2007-11-28 | 7 | 0d |  |  | DS; GP [50%] | 8h | 25,000 |
| 15 | 1.2.3.2 | **Construcción Funcionalidades** | 30.41d? | 2007-11-28 | 2008-01-15 |  | 0d |  |  |  | 139h | 818,750 |
| 16 | 1.2.3.2.1 | **Usuarios/Perfiles** | 3d? | 2007-11-28 | 2007-12-03 |  | 0d |  |  |  | 6h | 37,500 |
| 17 | 1.2.3.2.1.1 | Definición y Creación de Perfiles | 2d? | 2007-11-28 | 2007-11-30 | 14 | 0d |  |  | DS [25%] | 4h | 25,000 |
| 18 | 1.2.3.2.1.2 | Asociación de Tienda a Usuario y detección | 1d? | 2007-11-30 | 2007-12-03 | 17 | 0d |  |  | DS [25%] | 2h | 12,500 |
| 19 | 1.2.3.2.2 | **Clientes** | 1d? | 2007-12-03 | 2007-12-04 |  | 0d |  |  |  | 8h |  |
| 20 | 1.2.3.2.2.1 | Registro | 1d? | 2007-12-03 | 2007-12-04 | 16 | 0d |  |  |  | 8h |  |
| 21 | 1.2.3.2.3 | **Servicios** | 14.38d? | 2007-12-04 | 2007-12-26 |  | 0d |  |  |  | 48h | 300,000 |
| 22 | 1.2.3.2.3.1 | Registro/Actualización | 2d | 2007-12-04 | 2007-12-06 | 19 | 0d |  |  | DS [25%] | 4h | 25,000 |
| 23 | 1.2.3.2.3.2 | Impreso de Orden de Servicio | 8d? | 2007-12-06 | 2007-12-18 | 22 | 0d |  |  | DS [25%] | 16h | 100,000 |
| 24 | 1.2.3.2.3.3 | Manejo de Status | 0.62d? | 2007-12-18 | 2007-12-18 | 23 | 0d |  |  | DS [80%] | 4h | 25,000 |
| 25 | 1.2.3.2.3.4 | Reporte Técnico | 1.25d? | 2007-12-18 | 2007-12-20 | 24 | 0d |  |  | DS [80%] | 8h | 50,000 |
| 26 | 1.2.3.2.3.5 | Impreso de Garantía | 1.25d? | 2007-12-20 | 2007-12-21 | 25 | 0d |  |  | DS [80%] | 8h | 50,000 |
| 27 | 1.2.3.2.3.6 | Registro de Costos | 0.62d? | 2007-12-21 | 2007-12-21 | 26 | 0d |  |  | DS [80%] | 4h | 25,000 |
| 28 | 1.2.3.2.3.7 | Email con Cotización a Cliente | 0.62d? | 2007-12-21 | 2007-12-26 | 27 | 0d |  |  | DS [80%] | 4h | 25,000 |

| ID | WBS | Task | Duration | Start | Finish | Predecessors | Total slack | Constraint | Resources | Work | Cost |
| --- | --- | --- | --- | --- | --- | --- | --- | --- | --- | --- | --- |
| 29 | 1.2.3.2.4 | **Traslado de Equipos** | 3.75d? | 2007-12-26 | 2008-01-03 |  | 0d |  |  | 24h | 150,000 |
| 30 | 1.2.3.2.4.1 | Registro de Traslado | 0.62d? | 2007-12-26 | 2007-12-27 | 21 | 0d |  | DS [80%] | 4h | 25,000 |
| 31 | 1.2.3.2.4.2 | Impreso de Traslado | 1.25d? | 2007-12-27 | 2007-12-28 | 30 | 0d |  | DS [80%] | 8h | 50,000 |
| 32 | 1.2.3.2.4.3 | Tracking de Traslado | 1.25d? | 2007-12-28 | 2008-01-02 | 31 | 0d |  | DS [80%] | 8h | 50,000 |
| 33 | 1.2.3.2.4.4 | Cierre de Traslado | 0.62d? | 2008-01-02 | 2008-01-03 | 32 | 0d |  | DS [80%] | 4h | 25,000 |
| 34 | 1.2.3.2.5 | **Consultas** | 4.06d? | 2008-01-03 | 2008-01-09 |  | 0d |  |  | 26h | 162,500 |
| 35 | 1.2.3.2.5.1 | Clientes | 0.31d? | 2008-01-03 | 2008-01-03 | 29 | 0d |  | DS [80%] | 2h | 12,500 |
| 36 | 1.2.3.2.5.2 | Servicios | 1.25d? | 2008-01-03 | 2008-01-04 | 35 | 0d |  | DS [80%] | 8h | 50,000 |
| 37 | 1.2.3.2.5.3 | Traslados | 1.25d? | 2008-01-04 | 2008-01-08 | 36 | 0d |  | DS [80%] | 8h | 50,000 |
| 38 | 1.2.3.2.5.4 | Equipos por entregar y por cobrar | 1.25d? | 2008-01-08 | 2008-01-09 | 37 | 0d |  | DS [80%] | 8h | 50,000 |
| 39 | 1.2.3.2.6 | Pruebas Internas y Ajustes | 1.88d | 2008-01-09 | 2008-01-11 | 34 | 0d |  | DS [80%] | 12h | 75,000 |
| 40 | 1.2.3.2.7 | Guía de Usuario | 2.34d | 2008-01-11 | 2008-01-15 | 39 | 1.33d |  | DS [80%] | 15h | 93,750 |
| 41 | 1.2.4 | Pruebas de Certificación | 2.5d | 2008-01-11 | 2008-01-15 | 39 | 0d |  | GP [20%] | 4h |  |
| 42 | 1.2.5 | **Puesta en Marcha** | 1.18d | 2008-01-15 | 2008-01-16 |  | 0d |  |  | 8h |  |
| 43 | 1.2.5.1 | Adiestramiento | 4h | 2008-01-15 | 2008-01-16 | 41 | 0.55d | start no earlier than 2007-02-01 | GP | 4h |  |
| 44 | 1.2.5.2 | Implantación Fase I | 0.5d | 2008-01-15 | 2008-01-16 | 41 | 0d |  | OP | 4h |  |
| 45 | 1.3 | **Gerencia de Proyecto** | 31.25d | 2007-11-27 | 2008-01-15 |  | 1.49d |  |  | 24h |  |
| 46 | 1.3.1 | Planificación | 0.5d | 2007-11-27 | 2007-11-27 | 7 | 32.24d |  | GP | 4h |  |
| 47 | 1.3.2 | Control y Seguimiento | 31.25d | 2007-11-27 | 2008-01-15 | 7 | 1.49d | start no earlier than 2006-10-18 | GP [8%] | 20h |  |
