# Facturación PDVSA

Schedule from MS Project, 2008-05-20 to 2008-09-29, A marks actual dates.

## Calendars

- Estándar: Mon-Fri 08:00-12:00, 13:00-17:00; Sat-Sun off. Exceptions (off unless hours are given): 2008-06-24, 2008-07-21 to 2008-07-22, 2008-07-24.

## Resources

| Resource |
| --- |
| DS1 |
| GP |
| Usuario |
| Rvelasquez |
| OP |
| Consultor |
| DS2 |

## Schedule

| ID | WBS | Task | Type | Duration | Start | Finish | Predecessors | Complete | Remaining | Total slack | Constraint | Resources | Work | Actual work |
| --- | --- | --- | --- | --- | --- | --- | --- | --- | --- | --- | --- | --- | --- | --- |
| 1 | 1 | **Facturación PDVSA** |  | 90.21d? | 2008-05-20 A | 2008-09-29 |  | 84% | 14.54d? | 0d |  |  | 311.25h | 254.81h |
| 2 | 1.1 | **Inicio** |  | 0.25d | 2008-05-20 A | 2008-05-20 A |  | 100% |  |  |  |  | 2h | 2h |
| 3 | 1.1.1 | Preparación y Reunión de Arranque (Kickoff) |  | 0.25d | 2008-05-20 A | 2008-05-20 A |  | 100% |  |  | start no earlier than 2008-05-20 | GP | 2h | 2h |
| 4 | 1.2 | **Especificación de Requerimientos** |  | 38d? | 2008-05-21 A | 2008-07-15 A |  | 100% |  |  |  |  | 44h | 44h |
| 5 | 1.2.1 | Levantamiento de Información Etapa I |  | 9.38d? | 2008-05-21 A | 2008-06-03 A |  | 100% |  |  | start no earlier than 2008-05-21 | GP [10%]; Consultor [5%] | 10h | 10h |
| 6 | 1.2.2 | Levantamiento de Información Etapa II |  | 3.33d? | 2008-05-28 A | 2008-06-02 A |  | 100% |  |  | start no earlier than 2008-05-28 | GP [30%] | 8h | 8h |
| 7 | 1.2.3 | Elaboración del Informe Esp. de Req. |  | 8.33d | 2008-05-29 A | 2008-06-10 A |  | 100% |  |  | start no earlier than 2008-05-29 | GP [30%] | 20h | 20h |
| 8 | 1.2.4 | Revisión por parte del Equipo de Proyecto |  | 0.42d | 2008-06-10 A | 2008-06-10 A | 7 | 100% |  |  |  | GP [30%]; DS1 [50%] | 2h | 2h |
| 9 | 1.2.5 | Ajustes al Informe Especificación de Requerimientos |  | 1.67d | 2008-07-07 A | 2008-07-08 A |  | 100% |  |  | start no earlier than 2008-07-07 | GP [30%] | 4h | 4h |
| 10 | 1.2.6 | Revisión por parte del Cliente |  | 2d | 2008-07-08 A | 2008-07-10 A | 9 | 100% |  |  |  |  |  |  |
| 11 | 1.2.7 | Aprobación del Informe Especificación de Requerimientos | milestone | 0d | 2008-07-15 A | 2008-07-15 A |  | 100% |  |  | start no earlier than 2008-07-15 |  |  |  |
| 12 | 1.3 | Informe Especificación de Requerimientos Aprobado | milestone | 0d | 2008-07-15 A | 2008-07-15 A | 11 | 100% |  |  |  |  |  |  |
| 13 | 1.4 | **Configuración y Desarrollo** |  | 35.16d? | 2008-07-08 A | 2008-08-29 |  | 78% | 7.73d? | 20.38d |  |  | 208.25h | 172.25h |
| 14 | 1.4.1 | Análisis y Modelo de Datos |  | 1.5d? | 2008-07-15 A | 2008-07-16 A | 12 | 100% |  |  |  | DS1 | 12h | 12h |
| 15 | 1.4.2 | Cambios en Registro de Clientes (F-GNS-01 y F-GNS-02) |  | 0.25d? | 2008-07-08 A | 2008-07-08 A | 9 | 100% |  |  |  | DS1 | 2h | 2h |
| 16 | 1.4.3 | Actualización de Cliente en Facturación (F- GNS-03) |  | 1d? | 2008-07-08 A | 2008-07-09 A | 15 | 100% |  |  |  |  | 5h | 5h |
| 17 | 1.4.4 | **Pre-Facturación** |  | 4.62d? | 2008-07-15 A | 2008-07-23 A |  | 100% |  |  |  |  | 37h | 37h |
| 18 | 1.4.4.1 | Generación de Pre-Factura de Contrato (F- GNS-04) |  | 2.5d? | 2008-07-15 A | 2008-07-17 A | 12 | 100% |  |  |  | DS1 | 20h | 20h |
| 19 | 1.4.4.2 | Anulación de Pre-Factura (F- GNS-09) |  | 0.5d? | 2008-07-17 A | 2008-07-17 A | 18 | 100% |  |  |  | DS1 | 4h | 4h |
| 20 | 1.4.4.3 | Actualización Cliente en Pre-Factura (F- GNS-03) |  | 0.5d? | 2008-07-18 A | 2008-07-18 A | 19 | 100% |  |  |  | DS1 | 4h | 4h |
| 21 | 1.4.4.4 | Consulta de Pre-Facturas (F- GNS-05) |  | 1.12d? | 2008-07-18 A | 2008-07-23 A | 20 | 100% |  |  |  | DS1 | 9h | 9h |
| 22 | 1.4.5 | **Generación Proforma** |  | 6.5d? | 2008-07-23 A | 2008-08-01 A |  | 100% |  |  |  |  | 50.8h | 50.8h |
| 23 | 1.4.5.1 | Listado Contratos para Proforma (F- GNS-06) |  | 0.5d? | 2008-07-23 A | 2008-07-23 A | 17 | 100% |  |  |  | DS1 | 4h | 4h |
| 24 | 1.4.5.2 | Listado para actualización de datos para Proforma (F- GNS-06) |  | 0.62d? | 2008-07-23 A | 2008-07-25 A | 23 | 100% |  |  |  | DS1 | 5h | 5h |
| 25 | 1.4.5.3 | Impresión Pro-forma (F- GNS-06 y F- GNS-07) |  | 1.5d? | 2008-07-25 A | 2008-07-28 A | 24 | 100% |  |  |  | DS1 | 12h | 12h |
| 26 | 1.4.5.4 | Consulta de Proforma F- GNS-07) |  | 0.62d? | 2008-07-28 A | 2008-07-29 A | 25 | 100% |  |  |  | DS1 | 5h | 5h |
| 27 | 1.4.5.5 | Edición (adición y eliminación de Contratos en Proforma F- GNS-08) |  | 2d? | 2008-07-29 A | 2008-07-31 A | 26 | 100% |  |  |  | DS1 | 16h | 16h |
| 28 | 1.4.5.6 | Configuración columnas de Proforma por Cliente (F- GNS-10) |  | 1.1d? | 2008-07-31 A | 2008-08-01 A | 27 | 100% |  |  |  | DS1 | 8.8h | 8.8h |

Notes:
- 5: Estas horas se ejecutaron para levantamiento de información previo a la preparación de la propuesta.

| ID | WBS | Task | Type | Duration | Start | Finish | Predecessors | Complete | Remaining | Total slack | Free slack | Constraint | Resources | Work | Actual work |
| --- | --- | --- | --- | --- | --- | --- | --- | --- | --- | --- | --- | --- | --- | --- | --- |
| 29 | 1.4.6 | **Facturación PDVSA** |  | 5.3d? | 2008-08-01 A | 2008-08-08 A |  | 100% |  |  |  |  |  | 41.45h | 41.45h |
| 30 | 1.4.6.1 | Generación e impreso de Factura (F- GNS-11) |  | 2.68d? | 2008-08-01 A | 2008-08-06 A | 22 | 100% |  |  |  |  | DS1 | 21.45h | 21.45h |
| 31 | 1.4.6.2 | Ajuste en Consulta de Factura (F- GNS-11) |  | 0.88d? | 2008-08-06 A | 2008-08-07 A | 30 | 100% |  |  |  |  | DS1 | 7h | 7h |
| 32 | 1.4.6.3 | Ajuste en Anulación de Factura (F- GNS-11) |  | 0.5d? | 2008-08-07 A | 2008-08-07 A | 31 | 100% |  |  |  |  | DS1 | 4h | 4h |
| 33 | 1.4.6.4 | Auditoria de Cambios (F- GNS-13) |  | 1.12d? | 2008-08-07 A | 2008-08-08 A | 32 | 100% |  |  |  |  | DS1 | 9h | 9h |
| 34 | 1.4.7 | Reportes (5 reportes básicos) (F- GNS-12) |  | 3.75d? | 2008-08-08 | 2008-08-14 | 29 |  |  | 31.66d |  |  | DS1 | 30h |  |
| 35 | 1.4.8 | Pruebas internas y ajustes |  | 2d? | 2008-08-14 A | 2008-08-15 A | 34 | 100% |  |  |  |  | DS1 | 16h | 16h |
| 36 | 1.4.9 | **Pruebas de Certificación** |  | 8d | 2008-08-18 A | 2008-08-27 |  | 75% | 2d | 12.88d | 0d |  |  | 8h | 8h |
| 37 | 1.4.9.1 | Pruebas del Cliente |  | 5d | 2008-08-18 A | 2008-08-22 A | 35 | 100% |  |  |  |  |  |  |  |
| 38 | 1.4.9.2 | Ajustes |  | 1d | 2008-08-25 A | 2008-08-25 A | 37 | 100% |  |  |  |  | DS1 | 8h | 8h |
| 39 | 1.4.9.3 | Certificación por parte del Cliente |  | 2d | 2008-08-26 | 2008-08-27 | 38 |  |  | 12.88d |  |  |  |  |  |
| 40 | 1.4.10 | Apoyo en Pase a Producción |  | 1.83d | 2008-08-28 | 2008-08-29 | 36 |  |  | 12.88d | 0d |  | DS1 [20%]; OP [50%] | 6h |  |
| 41 | 1.4.11 | Cambios implantados en Producción | milestone | 0d | 2008-08-29 | 2008-08-29 | 40 |  |  | 12.88d | 0d |  |  |  |  |
| 42 | 1.5 | Soporte Post implantación |  | 7.5d | 2008-08-29 | 2008-09-10 | 41 |  |  | 12.88d |  |  | DS1 [20%]; GP [5%]; Consultor [5%] | 16h |  |
| 43 | 1.6 | **Cierre** |  | 0.38d | 2008-08-29 | 2008-09-01 |  |  |  | 20.01d |  |  |  | 3h |  |
| 44 | 1.6.1 | Preparación presentación de Cierre y Acta de Cierre |  | 0.12d | 2008-08-29 | 2008-08-29 | 41 |  |  | 20.01d | 0d |  | GP | 1h |  |
| 45 | 1.6.2 | Reunión Cierre de Proyecto |  | 0.25d | 2008-08-29 | 2008-09-01 | 44 |  |  | 20.01d |  |  | GP | 2h |  |
| 46 | 1.7 | **Gerencia de Proyecto** |  | 51.21d | 2008-07-15 A | 2008-09-29 |  | 95% | 2.34d | 0d |  |  |  | 38h | 36.56h |
| 47 | 1.7.1 | Planificación |  | 3.33d | 2008-07-15 A | 2008-07-18 A | 12 | 100% |  |  |  |  | GP [30%] | 8h | 8h |
| 48 | 1.7.2 | Control y Seguimiento |  | 36d | 2008-07-15 A | 2008-09-29 | 4 | 95% | 1.8d | 0d |  | finish no earlier than 2008-08-28 | GP [11.8%] | 30h | 28.56h |
