# Proyect1

Schedule from MS Project, 2009-03-30 to 2009-05-28.
gm

## Calendars

- Estándar: Mon-Fri 09:00-13:00, 15:00-19:00; Sat-Sun off.

## Resources

| Resource |
| --- |
| 10 |
| 13 |
| 15 |
| 14 |

## Schedule

| ID | WBS | Task | Type | Duration | Start | Finish | Predecessors | Total slack | Free slack | Constraint |
| --- | --- | --- | --- | --- | --- | --- | --- | --- | --- | --- |
| 1 | 1 | **WEB SITE Grupo Zelda** |  | 44d? | 2009-03-30 09:00 | 2009-05-28 19:00 |  | 0d |  |  |
| 2 | 1.1 | Configuración ambiente |  | 8h? | 2009-03-30 09:00 | 2009-03-30 19:00 |  | 42d | 0d | start no earlier than 2009-03-30 09:00 |
| 3 | 1.2 | Análisis |  | 8h? | 2009-03-31 09:00 | 2009-03-31 19:00 | 2 | 42d |  |  |
| 4 | 1.3 | GWT Recibe Material | milestone | 0h | 2009-04-03 09:00 | 2009-04-03 09:00 |  | 40d |  | start no earlier than 2009-04-03 09:00 |
| 5 | 1.4 | Asesoramiento 1 |  | 8h? | 2009-04-07 09:00 | 2009-04-07 19:00 |  | 37d |  | start no earlier than 2009-04-07 09:00 |
| 6 | 1.5 | **Diseño** |  | 16d? | 2009-04-21 09:00 | 2009-05-12 19:00 |  | 12d |  |  |
| 7 | 1.5.1 | **Gráfico** |  | 1d? | 2009-04-21 09:00 | 2009-04-21 19:00 |  | 12d |  |  |
| 8 | 1.5.1.1 | Propuesta Gráfica |  | 8h? | 2009-04-21 09:00 | 2009-04-21 19:00 |  | 12d | 0d | start no earlier than 2009-04-21 09:00 |
| 9 | 1.5.2 | Visual |  | 32h? | 2009-04-22 09:00 | 2009-04-27 19:00 | 8 | 12d | 0d | start no earlier than 2009-04-22 09:00 |
| 10 | 1.5.3 | Estructural |  | 80h? | 2009-04-28 09:00 | 2009-05-11 19:00 | 9 | 12d | 0d | finish no earlier than 2009-05-11 19:00 |
| 11 | 1.5.4 | Modelaje Datos |  | 8h? | 2009-05-12 09:00 | 2009-05-12 19:00 | 10 | 12d |  |  |
| 12 | 1.6 | Construcción Aplicaciones |  | 40h? | 2009-05-04 09:00 | 2009-05-08 19:00 |  | 4d |  | finish no earlier than 2009-05-08 19:00 |
| 13 | 1.7 | Asesoramiento 2 |  | 8h? | 2009-05-12 09:00 | 2009-05-12 19:00 | 10 | 12d |  |  |
| 14 | 1.8 | Pruebas |  | 8h? | 2009-05-15 09:00 | 2009-05-15 19:00 | 12 | 0d |  | finish no earlier than 2009-05-15 19:00 |
| 15 | 1.9 | Ajustes |  | 56h? | 2009-05-18 09:00 | 2009-05-26 19:00 | 14 | 0d |  | finish no earlier than 2009-05-26 19:00 |
| 16 | 1.10 | Carga de Contenido |  | 56h? | 2009-05-18 09:00 | 2009-05-26 19:00 | 12 | 2d |  | start no earlier than 2009-05-18 09:00 |
| 17 | 1.11 | **Documentación** |  | 5d? | 2009-05-15 09:00 | 2009-05-21 19:00 |  | 5d |  |  |
| 18 | 1.11.1 | Guia Usuario |  | 40h? | 2009-05-15 09:00 | 2009-05-21 19:00 |  | 5d |  | finish no earlier than 2009-05-21 19:00 |
| 19 | 1.12 | Adiestramiento |  | 8h? | 2009-05-27 09:00 | 2009-05-27 19:00 | 15 | 0d |  |  |
| 20 | 1.13 | Cursos |  | 8h? | 2009-05-27 09:00 | 2009-05-27 19:00 |  | 1d |  | start no earlier than 2009-05-27 09:00 |
| 21 | 1.14 | **Puesta Producción** |  | 1d? | 2009-05-28 09:00 | 2009-05-28 19:00 |  | 0d |  |  |
| 22 | 1.14.1 | Sitio WEB implantado |  | 8h? | 2009-05-28 09:00 | 2009-05-28 19:00 | 19 | 0d |  |  |
